# 3GPP_Release-2000

Schedule from MS Project, 2000-01-03 to 2009-03-12, A marks actual dates.

## Calendars

- Standard: Mon-Fri 08:00-12:00, 13:00-17:00; Sat-Sun off.

## Resources

| Resource |
| --- |
| NP |
| N1 |
| N2 |
| N3 |
| N4 |
| N5 |
| TP |
| T1 |
| T2 |
| T3 |
| RP |
| R1 |
| R2 |
| R3 |
| R4 |
| SP |
| S1 |
| S2 |
| S3 |
| S4 |
| S5 |
| PCG |
| GP |
| No |
| CN4 |
| ? |
| WG G2 |
| G2 |
| G1 |
| G4 |
| G3 |
| All |
| Generic |
| MLST |
| G5 |
| S3; G2 |
| WG T2 |
| GP;G1 |
| G4;G5 |
| OMA |
| GP-G2 |
| Yes |
| GP; |
| N4; |
| GP; N1 |
| CT5 |
| C5 |
| C1 |
| C4 |
| C3 |
| C6 |
| G1; |
| 4 |
| ct |
| c;s;r |
| CT;RAN;SA |
| G2, |
| G1; G3 |
| CT6 |
| CT1 |
| CT1, CT3, CT4 |
| C1, C3, C4 |
| CP |
| R5 |
| C |

## Schedule

| ID | WBS | Task | Duration | Start | Finish | Complete | Remaining | Baseline start | Baseline finish | Baseline duration | Total slack | Constraint | Resources | Work | Actual work | Text9 | Text6 | Text1 | Text8 | Text3 | Text5 |
| --- | --- | --- | --- | --- | --- | --- | --- | --- | --- | --- | --- | --- | --- | --- | --- | --- | --- | --- | --- | --- | --- |
| 1 | 1 | VERSION 2007 November 21st - proposed CT#37 updates | 1d | 2007-11-21 | 2007-11-21 |  |  | 2000-01-03 | 2000-01-03 | 1d | 341d | start no earlier than 2007-11-21 |  |  |  | 2044 |  |  |  |  |  |
| 2 | 2 | "CTRL + a" to display all the 3GPP fields | 1d | 2007-11-21 | 2007-11-21 |  |  | 2000-01-03 | 2000-01-03 | 1d | 341d | start no earlier than 2007-11-21 |  |  |  | 1462 |  |  |  |  |  |
| 3 | 3 | Content of Rel-8 (not frozen) and Rel-9 | 1d | 2007-11-21 | 2007-11-21 |  |  | 2000-01-03 | 2000-01-03 | 1d | 341d | start no earlier than 2007-11-21 |  |  |  | 2058 |  |  |  |  |  |
| 4 | 4 | Gantt: dark blue=done; light blue=to be done; grey: previous values; black=summary | 1d? | 2000-01-03 | 2000-01-03 |  |  |  |  |  | 2398d |  |  |  |  |  |  |  |  |  |  |
| 5 | 5 | Green=modified by CT#37 drafting (based on version 21st Nov) | 1d? | 2000-01-03 | 2000-01-03 |  |  |  |  |  | 2398d |  | CP | 8h |  |  |  |  |  |  |  |
| 7 | 6 | Release 8 Features | 1d? | 2004-06-28 | 2004-06-28 |  |  | 2000-01-03 | 2000-01-03 | 1d? | 1228d | start no earlier than 2004-06-28 | CT;RAN;SA | 8h |  |  | Rel-8 |  |  |  |  |
| 8 | 7 | **3G Long Term Evolution - Evolved Packet System RAN part** | 644d? | 2006-09-25 A | 2009-03-12 | 22% | 503.12d? | 2006-09-25 | 2008-09-12 | 515d? | 0d |  | RP | 26584h | 4779.2h |  | Rel-8 | LTE | MCC_RAN |  |  |
| 9 | 7.1 | LTE – Physical Layer | 255d? | 2006-09-25 A | 2007-09-14 | 80% | 51d? | 2006-09-25 | 2007-09-14 | 255d? | 389d | finish no earlier than 2007-09-14 | R1 | 2040h | 1632h |  | Rel-8 | LTE-Phys | MCC_RAN | 36.2xy |  |
| 10 | 7.2 | LTE – Radio Interface Layer 2 and 3 Protocol Aspect | 320d? | 2006-09-25 A | 2007-12-14 | 50% | 160d? | 2006-09-25 | 2007-12-14 | 320d? | 324d | finish no earlier than 2007-12-14 | R2 | 2560h | 1280h |  | Rel-8 | LTE-L23 | MCC_RAN | 36.3xy |  |
| 11 | 7.3 | LTE – eUTRAN Interfaces | 320d? | 2006-09-25 A | 2007-12-14 | 51% | 156.8d? | 2006-09-25 | 2007-12-14 | 320d? | 324d | finish no earlier than 2007-12-14 | R3 | 2560h | 1305.6h |  | Rel-8 | LTE-interfaces | MCC_RAN | 36.4xy |  |
| 12 | 7.4 | LTE – RF Radio Transmission/Reception, System Performance Requirements and Conformance Testing | 385d? | 2006-09-25 A | 2008-03-14 | 2% | 377.3d? | 2006-09-25 | 2008-03-14 | 385d? | 259d | finish no earlier than 2008-03-14 | R4 | 3080h | 61.6h |  | Rel-8 | LTE-RF | MCC_RAN | 36.1xy |  |
| 13 | 7.5 | LTE FDD repeaters | 261d? | 2007-09-14 | 2008-09-12 |  |  | 2007-09-14 | 2008-09-12 | 261d? | 129d | finish no earlier than 2008-09-12 | R4 | 2088h |  |  | Rel-8 | LTE-Repeaters | MCC_RAN | TS 36.x, TS 25.113 |  |
| 14 | 7.6 | **LTE – Terminal Conformance Test Specifications** | 336d? | 2007-06-01 A | 2008-09-12 | 3% | 327.6d? | 2007-06-01 | 2008-09-12 | 336d? | 129d |  | R5 | 6632h | 134.4h |  | Rel-8 | LTE-UEConTest | MCC_RAN |  | catherine.salinoc@nectech.fr |
| 15 | 7.6.1 | 3G Long Term Evolution – Terminal Protocol Conformance Test Specifications | 336d? | 2007-06-01 A | 2008-09-12 | 3% | 325.92d? | 2007-06-01 | 2008-09-12 | 336d? | 129d | finish no earlier than 2008-09-12 | R5 | 2688h | 80.64h |  | Rel-8 | LTE-UEConTest_SIG | Stoyan Baev | TS 36.508, 36.523-1, 36.523-2, 36.523-3 | catherine.salinoc@nectech.fr, Jacob.John@motorola.com |
| 16 | 7.6.2 | 3G Long Term Evolution – Terminal Radio Transmission and Reception Conformance Test Specifications | 336d? | 2007-06-01 A | 2008-09-12 | 2% | 329.28d? | 2007-06-01 | 2008-09-12 | 336d? | 129d | finish no earlier than 2008-09-12 | R5 | 2688h | 53.76h |  | Rel-8 | LTE-UEConTest_RF | Stoyan Baev | TS 36.508, 36.521-1, 36.521-2 | andrea_leonardi@agilent.com |
| 17 | 7.7 | E-UTRAN Network Resource Model (NRM) Integration Reference Point (IRP) | 309d? | 2008-01-07 | 2009-03-12 |  |  | 2005-09-02 | 2008-12-15 | 857d? | 0d | finish no earlier than 2009-03-12 | S5 | 2472h |  |  | Rel-8 | E-UTRAN-OAM |  | new 32.xyz |  |
| 18 | 8 | **3GPP System Architecture Evolution Specification - Evolved Packet System (non RAN aspects)** | 762d? | 2006-04-12 A | 2009-03-12 | 25% | 574.18d? | 2006-04-12 | 2008-06-20 | 573d? | 0d |  | S2; C1; C3; C4; S1 | 224877h | 39881.3h |  | Rel-8 | SAES | Maurice | 23.228, 23.279 | osok.song@samsung.com |
| 19 | 8.1 | Requirements for evolution of the 3GPP system architecture | 387d? | 2006-06-08 A | 2007-11-30 A | 100% |  | 2006-06-08 | 2007-01-12 | 157d? |  | finish no earlier than 2007-11-30 | S1 | 3096h | 3096h |  | Rel-8 | AIPN-SAE | Alain | 22.278 | michael.kurz@t-mobile.at |
| 20 | 8.2 | **High level and common (for all accesses) functions** | 522d? | 2007-01-02 A | 2008-12-31 | 13% | 453.73d? | 2007-01-02 | 2008-05-30 | 369d? | 51d |  | S2; C1; C3; C4 | 41388.8h | 3377.6h |  | Rel-8 | EPS-ComF |  |  |  |
| 21 | 8.2.1 | Stage 2 of High level functions | 309d? | 2007-01-02 A | 2008-03-07 | 80% | 61.8d? | 2007-01-02 | 2007-09-07 | 179d? | 264d | finish no earlier than 2008-03-07 | S2 | 2472h | 1977.6h |  | Rel-8 | SAES-SA-HLF |  |  |  |
| 22 | 8.2.2 | Stage 3 (CT1) for SAE impact on services, network functions and capabilities | 485d? | 2007-02-05 A | 2008-12-15 | 6% | 455.9d? | 2007-02-05 | 2008-03-14 | 290d? | 64d | finish no earlier than 2008-12-15 | C1 | 3880h | 232.8h |  | Rel-8 | SAES-St3-CT1imp | Andrijana |  | robert.zaus@nsn.com |
| 23 | 8.2.3 | Stage 3 (CT3) for SAE impact on existing capabilities | 290d? | 2007-02-05 A | 2008-03-14 | 5% | 275.5d? | 2007-02-05 | 2008-03-14 | 290d? | 259d | start no earlier than 2007-02-05 | C3 | 2320h | 116h |  | Rel-8 | SAES-St3-CT3imp |  |  |  |
| 24 | 8.2.4 | Stage 3 (CT4) of SAE impact on existing capabilities | 345d? | 2007-02-05 A | 2008-05-30 | 8% | 316d? | 2007-02-05 | 2008-03-14 | 290d? | 204d | finish no earlier than 2008-05-30 | C4 | 2760h | 232h |  | Rel-8 | SAES-St3-impacts |  |  |  |
| 25 | 8.2.5 | Stage 2/3 for Network selection procedures | 485d? | 2007-02-05 | 2008-12-15 |  |  | 2007-02-05 | 2008-03-14 | 290d? | 64d | finish no earlier than 2008-12-15 | C1 | 3880h |  |  | Rel-8 | SAES-St3-netsel | Andrijana |  | robert.zaus@nsn.com |
| 26 | 8.2.6 | Stage 3 PCC aspects of SAE | 498d? | 2007-02-05 A | 2008-12-31 | 10% | 448.2d? | 2007-02-05 | 2008-03-14 | 290d? | 51d | finish no earlier than 2008-12-31 | C3 | 3984h | 398.4h |  | Rel-8 | SAES-St3-PCC | MEREDITH, John M |  |  |
| 27 | 8.2.7 | Stage 3 of Interworking between EPC and external PDNs (SGi) | 290d? | 2007-02-05 | 2008-03-14 |  |  | 2007-02-05 | 2008-03-14 | 290d? | 259d | start no earlier than 2007-02-05 | C3 | 2320h |  |  | Rel-8 | SAES-St3-intwk |  |  |  |
| 28 | 8.2.8 | Stage 3 of SAE / LTE identities | 345d? | 2007-02-05 A | 2008-05-30 | 10% | 310.5d? | 2007-02-05 | 2007-11-30 | 215d? | 204d | finish no earlier than 2008-05-30 | C4 | 2760h | 276h |  | Rel-8 | SAES-St3-IDs |  |  |  |
| 29 | 8.2.9 | Unified guidelines of Diameter usage within 3GPP | 181d? | 2007-09-21 A | 2008-05-30 | 10% | 162.9d? | 2007-09-21 | 2008-05-30 | 181d? | 204d | finish no earlier than 2008-05-30 | C3 | 1448h | 144.8h |  | Rel-8 | SAES-DIAM | MEREDITH, John M | 29.909 |  |

Notes:
- 8: Text4: Takehiro Nakamura (NTT DoCoMo)
- 9: Text4: Sadayuki Abeta, NTT DoCoMo
- 10: Text4: Benoist Sebire, Nokia
- 11: Text4: Mattias Wahlqvist, Ericsson
- 12: Text4: Frank Lamprecht, Siemens
- 13: Text4: Alf Ahlström, Powerwave Technologies. Ralf Michanikl, Andrew Wireless Corporation
- 14: BB place holder for a number of RAN5 Tasks / Text4: Catherine Salinoc, NEC
- 15: Dependent on RAN as well as on CT/SA WIs / Text4: Catherine Salinoc (NEC), Jacob John (Motorola)
- 16: Text4: Andrea Leonardi (Agilent)
- 17: 12/07 SA#38 WID Approval / Text4: Ericsson
- 18: S2#52: Specification phase created. New WID approved SA#32 / Text4: Osok Song (Samsung)
- 19: Text4: Michael Kurz (T-Mobile International)
- 22: Text4: Robert Zaus (Nokia Siemens Networks)
- 25: Text4: Robert Zaus (Nokia Siemens Networks)
- 26: C3-46: Progress made but completion date now estimated end 2008
- 29: CP-37: WI approved. C3-46: early draft of 29.909 available. / Text4: Javier Gonzalez Gallego, Huawei

| ID | WBS | Task | Type | Duration | Start | Finish | Complete | Remaining | Baseline start | Baseline finish | Baseline duration | Total slack | Constraint | Resources | Work | Actual work | Text1 | Text6 | Text5 | Text8 | Text12 |
| --- | --- | --- | --- | --- | --- | --- | --- | --- | --- | --- | --- | --- | --- | --- | --- | --- | --- | --- | --- | --- | --- |
| 30 | 8.3 | **SAE for LTE access** |  | 369d? | 2007-01-02 A | 2008-05-30 | 24% | 279.75d? | 2007-01-02 | 2008-03-14 | 314d? | 204d |  | S2; C1; C3; C4 | 45160h | 9047.66h | SAES-SA-FP_LTE | Rel-8 |  |  |  |
| 31 | 7.2.2.1 | **SAES-SA-FP_LTE with GTP variant** |  | 369d? | 2007-01-02 A | 2008-05-30 | 48% | 192.62d? | 2007-01-02 | 2007-12-03 | 240d? | 204d |  | S2; C4 | 10944h | 3768h | SAES-SA-FP_LTE-GTP | Rel-8 |  |  |  |
| 32 | 8.3.1.1 | Stage 2 for SAES-SA-FP_LTE with GTP variant |  | 309d? | 2007-01-02 A | 2008-03-07 | 90% | 30.9d? | 2007-01-02 | 2007-12-03 | 240d? | 264d | finish no earlier than 2008-03-07 | S2 | 2472h | 2224.8h | SAES-SA-FP_LTE-GTP | Rel-8 |  |  |  |
| 33 | 8.3.1.2 | Stage 3 for GTP v2 protocol |  | 345d? | 2007-02-05 A | 2008-05-30 | 10% | 310.5d? | 2007-02-05 | 2007-11-30 | 215d? | 204d | finish no earlier than 2008-05-30 | C4 | 2760h | 276h | SAES-St3-EPC | Rel-8 |  |  |  |
| 34 | 7.2.2.2 | **SAES-SA-FP_LTE with PMIP variant** |  | 369d? | 2007-01-02 A | 2008-05-30 | 35% | 240.79d? | 2007-01-02 | 2007-12-03 | 240d? | 204d |  | S2 | 10944h | 3802.46h | SAES-SA-FP_LTE-IETF | Rel-8 |  |  |  |
| 35 | 8.3.2.1 | Stage 2 for SAES-SA-FP_LTE with PMIP variant |  | 309d? | 2007-01-02 A | 2008-03-07 | 90% | 30.9d? | 2007-01-02 | 2007-12-03 | 240d? | 264d | finish no earlier than 2008-03-07 | S2 | 2472h | 2224.8h | SAES-SA-FP_LTE-IETF | Rel-8 |  |  |  |
| 36 | 8.3.2.2 | Stage 3 for PMIP protocol within EPC |  | 345d? | 2007-02-05 A | 2008-05-30 | 10% | 310.5d? | 2007-02-05 | 2007-11-30 | 215d? | 204d | finish no earlier than 2008-05-30 | C4 | 2760h | 276h | SAES-St3-EPC | Rel-8 |  |  |  |
| 37 | 8.3.2.3 | Stage 3 for protocol between EPCs |  | 345d? | 2007-02-05 A | 2008-05-30 | 10% | 310.5d? | 2007-02-05 | 2007-11-30 | 215d? | 204d | finish no earlier than 2008-05-30 | C4 | 2760h | 276h | SAES-St3-EPC_EPC | Rel-8 |  |  |  |
| 38 | 8.3.3 | Stage 3 for UE NAS mobility procedures in idle and active mode |  | 290d? | 2007-02-05 A | 2008-03-14 | 8% | 266.8d? | 2007-02-05 | 2008-03-14 | 290d? | 259d | start no earlier than 2007-02-05 | C1 | 2320h | 185.6h | SAES-St3-NASmob | Rel-8 |  |  |  |
| 39 | 8.3.4 | Stage 3 for Session management, bearer control and QoS aspects |  | 290d? | 2007-02-05 A | 2008-03-14 | 8% | 266.8d? | 2007-02-05 | 2008-03-14 | 290d? | 259d | start no earlier than 2007-02-05 | C1 | 2320h | 185.6h | SAES-St3-BCQOS | Rel-8 |  |  |  |
| 40 | 8.3.5 | Stage 3 for security aspects for LTE Access |  | 290d? | 2007-02-05 A | 2008-03-14 | 8% | 266.8d? | 2007-02-05 | 2008-03-14 | 290d? | 259d | start no earlier than 2007-02-05 | C1 | 2320h | 185.6h | SAES-St3-CT1sec | Rel-8 |  |  |  |
| 41 | 8.3.6 | Stage 3 for QoS mechanisms |  | 290d? | 2007-02-05 | 2008-03-14 |  |  | 2007-02-05 | 2008-03-14 | 290d? | 259d | start no earlier than 2007-02-05 | C3 | 2320h |  | SAES-St3-QoS | Rel-8 |  |  |  |
| 42 | 8.3.7 | Stage 3 for EPC - HSS interface |  | 345d? | 2007-02-05 A | 2008-05-30 | 10% | 310.5d? | 2007-02-05 | 2007-11-30 | 215d? | 204d | finish no earlier than 2008-05-30 | C4 | 2760h | 276h | SAES-St3-EPC_HSS | Rel-8 |  |  |  |
| 43 | 8.4 | **SAE for Interoperation between LTE and legacy cellular PS accesses** |  | 485d? | 2007-02-05 A | 2008-12-15 | 20% | 390.24d? | 2007-02-05 | 2008-03-20 | 294d? | 64d |  | S2; C1; C3; C4 | 38120h | 7447.9h | SAES-SA-FP_3GPP | Rel-8 |  |  |  |
| 44 | 8.4.1 | Stage 3 for Inter-system mobility between E-UTRAN and 2G/3G |  | 485d? | 2007-02-05 A | 2008-12-12 | 4% | 465.6d? |  |  |  | 64d | start no earlier than 2007-02-05 | C1 | 3880h | 155.2h | SAES-St3-intersys-2_3G | Rel-8 | robert.zaus@nsn.com | Andrijana |  |
| 45 | 8.4.2 | Stage 2 for Interoperation between LTE and 2G/3G |  | 285d? | 2007-02-05 A | 2008-03-07 | 80% | 57d? | 2007-02-05 | 2007-12-31 | 236d? | 264d | finish no earlier than 2008-03-07 | S2 | 2280h | 1824h | EPSto2_3G | Rel-8 |  |  |  |
| 46 | 8.4.3 | Stage 3 of EPC - GPRS |  | 345d? | 2007-02-05 A | 2008-05-30 | 10% | 310.5d? | 2007-02-05 | 2007-11-30 | 215d? | 204d | finish no earlier than 2008-05-30 | C4 | 2760h | 276h | SAES-St3-EPC_GPRS | Rel-8 |  |  |  |
| 47 | 8.4.4 | Stage 3 of EPC to UTRAN |  | 345d? | 2007-02-05 A | 2008-05-30 | 10% | 310.5d? | 2007-02-05 | 2007-11-30 | 215d? | 204d | finish no earlier than 2008-05-30 | C4 | 2760h | 276h | SAES-St3-EPC_UTRAN | Rel-8 |  |  |  |
| 48 | 8.4.5 | Stage 3 of EPC to 3GPP2 |  | 345d? | 2007-02-05 A | 2008-05-30 | 10% | 310.5d? | 2007-02-05 | 2007-11-30 | 215d? | 204d | finish no earlier than 2008-05-30 | C4 | 2760h | 276h | SAES-St3-EPC_3GPP2 | Rel-8 |  |  |  |
| 49 | 8.4.6 | Stage 2 for Interoperation between LTE and CDMA2000 |  | 190d? | 2007-06-18 A | 2008-03-07 | 80% | 38d? | 2007-06-18 | 2008-03-20 | 199d? | 264d | finish no earlier than 2008-03-07 | S2 | 1520h | 1216h | EPStoC2k | Rel-8 |  |  |  |
| 50 | 8.4.7 | Stage 3 for Inter-system mobility between E-UTRAN and CDMA2000 |  | 485d? | 2007-02-05 A | 2008-12-15 | 3% | 470.45d? | 2007-02-05 | 2008-03-14 | 290d? | 64d | finish no earlier than 2008-12-15 | C1 | 3880h | 116.4h | SAES-St3-intersys-C2k | Rel-8 | robert.zaus@nsn.com | Andrijana |  |
| 51 | 8.4.8 | Stage 3 for MME - SGSN "signalling free" protocol |  | 345d? | 2007-02-05 A | 2008-05-30 | 10% | 310.5d? | 2007-02-05 | 2007-11-30 | 215d? | 204d | finish no earlier than 2008-05-30 | C4 | 2760h | 276h | SAES-St3-MME_SGSN | Rel-8 |  |  |  |
| 52 | 8.5 | **SAE for support of non-3GPP accesses** |  | 509d? | 2007-01-02 A | 2008-12-15 | 24% | 386.45d? | 2007-01-02 | 2008-03-14 | 314d? | 64d |  | S2; C1; C3; C4 | 46920h | 7992h | SAES-SA-FP_n3GPP | Rel-8 |  |  |  |
| 53 | 7.2.4.1 | Stage 2 for Host-based Mobility aspects |  | 309d? | 2007-01-02 A | 2008-03-07 | 90% | 30.9d? | 2007-01-02 | 2007-12-03 | 240d? | 264d | finish no earlier than 2008-03-07 | S2 | 2472h | 2224.8h | SAES-SA-FP_n3GPP-HBMob | Rel-8 |  |  |  |
| 54 | 7.2.4.2 | Stage 2 for Network-based Mobility aspects |  | 309d? | 2007-01-02 A | 2008-03-07 | 70% | 92.7d? | 2007-01-02 | 2007-12-03 | 240d? | 264d | finish no earlier than 2008-03-07 | S2 | 2472h | 1730.4h | SAES-SA-FP_n3GPP-NBMob | Rel-8 |  |  |  |
| 55 | 8.5.3 | Stage 2 for Optimised Handover with WiMAX |  | 255d? | 2007-06-25 A | 2008-06-13 | 39% | 155.55d? | 2007-06-25 | 2008-03-07 | 185d? | 194d | finish no earlier than 2008-06-13 | S2 | 2040h | 795.6h | SAES-SA-FP_n3GPP-OptWIMAX | Rel-8 |  |  |  |
| 56 | 8.5.4 | Stage 3 for Access to the EPC via non-3GPP access networks |  | 485d? | 2007-02-05 A | 2008-12-15 | 10% | 436.5d? | 2007-02-05 | 2008-03-14 | 290d? | 64d | finish no earlier than 2008-12-15 | C1 | 3880h | 388h | SAES-St3-non-3GPP | Rel-8 | robert.zaus@nsn.com | Andrijana |  |
| 57 | 8.5.5 | Stage 3 for Mobility management based on mobile IP |  | 485d? | 2007-02-05 A | 2008-12-15 | 30% | 339.5d? | 2007-02-05 | 2008-03-14 | 290d? | 64d | finish no earlier than 2008-12-15 | C1 | 3880h | 1164h | SAES-St3-CT1MIP | Rel-8 | robert.zaus@nsn.com | Andrijana |  |
| 58 | 8.5.6 | Stage 3 for Inter-system mobility between E-UTRAN and non 3GPP accesses |  | 485d? | 2007-02-05 A | 2008-12-12 | 4% | 465.6d? |  |  |  | 64d | start no earlier than 2007-02-05 | C1 | 3880h | 155.2h | SAES-St3-intersys-n3GPP | Rel-8 | robert.zaus@nsn.com | Andrijana |  |
| 59 | 8.5.7 | Stage 3 security aspects for non3GPP Access |  | 485d? | 2007-02-05 A | 2008-12-15 | 5% | 461.8d? | 2007-02-05 | 2008-03-14 | 290d? | 64d | finish no earlier than 2008-12-15 | C1 | 3880h | 185.6h | SAES-St3-CT1sec-MIP | Rel-8 | robert.zaus@nsn.com | Andrijana |  |
| 60 | 8.5.8 | Stage 3 for interfaces within EPC |  | 183d? | 2007-09-19 A | 2008-05-30 | 10% | 164.7d? | 2007-09-19 | 2007-12-20 | 67d? | 204d | finish no earlier than 2008-05-30 | C4 | 1464h | 146.4h | EPS-int_ifSt3 | Rel-8 |  |  |  |
| 61 | 8.5.9 | Stage 3 for Interfaces EPC - non-3GPP IP access |  | 345d? | 2007-02-05 A | 2008-05-30 | 10% | 310.5d? | 2007-02-05 | 2007-11-30 | 215d? | 204d | finish no earlier than 2008-05-30 | C4 | 2760h | 276h | SAES-St3-EPC_n3G | Rel-8 |  |  |  |
| 62 | 8.5.10 | Stage 3 for AAA/HSS related |  | 345d? | 2007-02-05 A | 2008-05-30 | 10% | 310.5d? | 2007-02-05 | 2007-11-30 | 215d? | 204d | finish no earlier than 2008-05-30 | C4 | 2760h | 276h | SAES-St3-AAA_HSS | Rel-8 |  |  |  |
| 63 | 8.5.11 | Stage 3 for EPC - AAA interface |  | 215d? | 2007-02-05 A | 2007-11-30 | 10% | 193.5d? | 2007-02-05 | 2007-11-30 | 215d? | 334d | finish no earlier than 2007-11-30 | C4 | 1720h | 172h | SAES-St3-EPC_AAA | Rel-8 |  |  |  |
| 64 | 8.5.12 | Deleted (already covered) SAES-SA-FP_n3GPP Optimised Handover with CDMA | milestone | 0d? | 2007-06-25 A | 2007-06-25 A | 100% |  | 2007-06-25 | 2007-06-25 | 0d? |  | finish no earlier than 2007-06-25 | S2 |  |  | SAES-SA-FP_n3GPP-OptCDMA | Rel-8 |  |  |  |
| 65 | 8.6 | Functions and procedures for SAE to support LTE MBMS |  | 255d? | 2007-06-25 A | 2008-06-13 | 40% | 153d? | 2007-06-25 | 2008-06-13 | 255d? | 194d | finish no earlier than 2008-06-13 | S2 | 2040h | 816h | SAES-SA-FP_LTEMBMS | Rel-8 |  |  |  |
| 66 | 8.7 | Functions and procedures for SAE to support LCS |  | 220d? | 2007-08-13 A | 2008-06-13 | 15% | 187d? | 2007-08-13 | 2008-06-13 | 220d? | 194d | finish no earlier than 2008-06-13 | S2 | 1760h | 264h | SAES-SA-FP_LCS | Rel-8 |  |  |  |
| 67 | 8.8 | Single Radio Voice Call Continuity for 3GPP |  | 379d? | 2007-01-02 A | 2008-06-13 | 50% | 189.5d? | 2007-01-02 | 2008-03-07 | 309d? | 194d | finish no earlier than 2008-06-13 | S2 | 3032h | 1516h | SAES-SA-SR_VCC_3G | Rel-8 |  |  |  |
| 68 | 8.9 | Voice Call Continuity for CDMA2000 1X |  | 255d? | 2007-06-25 A | 2008-06-13 | 60% | 102d? | 2007-06-25 | 2008-03-07 | 185d? | 194d | finish no earlier than 2008-06-13 | S2 | 2040h | 1224h | SAES-SA-VCC_1X | Rel-8 |  |  |  |
| 69 | 8.10 | SAE impacts on IMS |  | 379d? | 2007-01-02 A | 2008-06-13 | 20% | 303.2d? | 2007-01-02 | 2008-03-07 | 309d? | 194d | finish no earlier than 2008-06-13 | S2 | 3032h | 606.4h | SAES-SA-on_IMS | Rel-8 |  |  |  |
| 70 | 8.11 | SAE aspects of Emergency Calls |  | 245d? | 2007-10-08 | 2008-09-12 |  |  | 2007-10-08 | 2008-06-20 | 185d? | 129d | finish no earlier than 2008-09-12 | S2 | 1960h |  | SAES-SA-EmCall | Rel-8 |  |  |  |
| 71 | 8.12 | EPC Network Resource Model (NRM) Integration Reference Point (IRP) |  | 309d? | 2008-01-07 | 2009-03-12 |  |  | 2005-09-02 | 2008-12-15 | 857d? | 0d | finish no earlier than 2009-03-12 | S5 | 2472h |  | EPC-OAM | Rel-8 |  |  |  |
| 72 | 8.13 | EPC Charging |  | 309d? | 2008-01-07 | 2009-03-12 |  |  | 2005-09-02 | 2008-12-15 | 857d? | 0d | finish no earlier than 2009-03-12 | S5 | 2472h |  | EPC-CH | Rel-8 |  |  |  |
| 73 | 8.14 | Deleted - CT1 aspects of SAES | milestone | 0d? | 2007-09-04 A | 2007-09-27 A | 100% |  | 2007-09-04 | 2007-09-27 | 0d? |  | start no earlier than 2007-09-04 | CP; C1 |  |  | SAES-St3 | Rel-8 |  |  |  |
| 74 | 8.15 | Deleted - CT1 aspects of SAES | milestone | 0d? | 2007-09-04 A | 2007-09-04 A | 100% |  | 2007-09-04 | 2007-09-04 | 0d? |  | start no earlier than 2007-09-04 | C1 |  |  | SAES-St3 | Rel-8 |  |  |  |
| 75 | 8.16 | Deleted - Interoperability | milestone | 0d? | 2008-03-14 A | 2008-03-14 A | 100% |  | 2008-03-14 | 2008-03-14 | 0d? |  | start no earlier than 2008-03-14 | C1 |  |  | SAES-St3-interop | Rel-8 |  |  |  |
| 76 | 8.17 | Deleted - CT3 aspects of SAES | milestone | 0d? | 2007-09-04 A | 2007-09-04 A | 100% |  | 2007-09-04 | 2007-09-04 | 0d? |  | start no earlier than 2007-09-04 | C3 |  |  | SAES-St3 | Rel-8 |  |  |  |
| 77 | 8.18 | Deleted - CT4 aspects of SAES | milestone | 0d? | 2007-09-04 A | 2007-09-04 A | 100% |  | 2007-09-04 | 2007-09-04 | 0d? |  | start no earlier than 2007-09-04 | C4 |  |  | SAES-St3 | Rel-8 |  |  |  |
| 78 | 8.19 | Deleted - UE to EPC NAS signalling (incl. MBMS and QoS aspects) | milestone | 0d? | 2008-03-14 A | 2008-03-14 A | 100% |  | 2008-03-14 | 2008-03-14 | 0d? |  | start no earlier than 2008-03-14 | C1 |  |  | SAES-St3-sig | Rel-8 |  |  |  |
| 79 | 8.20 | Deleted -User and Control plane protocols | milestone | 0d? | 2007-09-21 A | 2007-09-21 A | 100% |  | 2007-09-21 | 2007-09-21 | 0d? |  | start no earlier than 2007-09-21 | C4 |  |  | SAES-St3-prot | Rel-8 |  |  |  |
| 80 | 8.21 | Deleted - GPRS enhancements for LTE access | milestone | 0d? | 2007-09-04 A | 2007-09-04 A | 100% |  | 2007-09-04 | 2007-09-04 | 0d? |  | start no earlier than 2007-09-04 | S2 |  |  | SAES-GPRS_LTE | Rel-8 | chris.pudney@vodafone.com | Maurice |  |
| 81 | 8.22 | Deleted - Architecture enhancements for non-3GPP accesses | milestone | 0d? | 2007-09-04 A | 2007-09-04 A | 100% |  | 2007-09-04 | 2007-09-04 | 0d? |  | start no earlier than 2007-09-04 | S2 |  |  | SAES-non_3GPP | Rel-8 | Irfan.Ali@motorola.com | Maurice |  |
| 82 | 8.23 | Deleted: Stage 2 of architecture for the 3GPP System Architecture Evolution | milestone | 0d? | 2007-10-02 A | 2007-10-02 A | 100% |  | 2007-10-02 | 2007-10-02 | 0d? |  | start no earlier than 2007-10-02 | S2 |  |  | SAES-St2 | Rel-8 | chris.pudney@vodafone.com | Maurice | SP-34 |
| 83 | 8.24 | deleted - SA aspects of System Architecture Evolution |  | 384d? | 2006-04-12 A | 2007-10-02 A | 100% |  | 2006-04-12 | 2007-10-02 | 384d? |  | finish no earlier than 2007-10-02 | S2 | 3072h | 3072h | SAES-SA | Rel-8 |  |  |  |
| 84 | 9 | GERAN support for GERAN - 3G Long Term Evolution interworking |  | 381d? | 2006-09-08 A | 2008-02-22 | 35% | 247.65d? | 2006-09-08 | 2008-02-22 | 381d? | 274d | finish no earlier than 2008-02-22 | GP | 3048h | 1066.8h | GELTE | Rel-8 | sergio.parolari@nsn.com, vlora.rexhepi@nokia.com | Paolo |  |

Notes:
- 37: Name changed from "Stage 3 for PMIP protocol between EPCs" to incorporate GTP part also
- 44: Text4: Robert Zaus (Nokia Siemens Networks)
- 50: Text4: Robert Zaus (Nokia Siemens Networks)
- 56: Text4: Robert Zaus (Nokia Siemens Networks)
- 57: Text4: Robert Zaus (Nokia Siemens Networks)
- 58: Text4: Robert Zaus (Nokia Siemens Networks)
- 59: Text4: Robert Zaus (Nokia Siemens Networks)
- 66: SA2 need RAN outputs (RAN dependencies)
- 70: Progress expected S2#60
- 71: 12/07 SA#38 WID Approval / Text3: new 32.xyz / Text4: Huawei
- 72: 12/07 SA#38 WID Approval / Text3: 32.240/ 296/ 251/ 252/ 298/ 299 / Text4: NSN
- 77: Text3: 29.803
- 80: SP-34: GPRS enhancements for LTE access item created. / Text3: 23.401 / Text4: Chris Pudney (Vodafone)
- 81: SP-34: Architecture enhancements for non-3GPP accesses item created. / Text3: 23.402 / Text4: Irfan Ali (Motorola)
- 82: THIS LINE IS DELETED, replaced by the 2 Architecture parallel tracks. / Text3: 23.002, 23.060, 23.107, 23.203, 23.228, 23.234, 23.246, 23.271, 23.279 / Text4: Chris Pudney (Vodafone)
- 83: S2 internal target is September 2007
- 84: Text3: 24.008, 43.055, 43.129, 43.246, 44.018, 44.060, 45.002, 45.008, 45.010, 48.008,48.018, 51.010 / Text4: Vlora Rexhepi - van der Pol, NOKIA Corporation, / Sergio Parolari, Nokia Siemens Networks S.p.A.

| ID | WBS | Task | Type | Duration | Start | Finish | Complete | Remaining | Baseline start | Baseline finish | Baseline duration | Total slack | Constraint | Resources | Work | Actual work | Text1 | Text4 | Text6 | Text3 | Text5 | Text8 |
| --- | --- | --- | --- | --- | --- | --- | --- | --- | --- | --- | --- | --- | --- | --- | --- | --- | --- | --- | --- | --- | --- | --- |
| 85 | 10 | **Contact Manager for 3GPP UICC applications** |  | 447d? | 2006-06-22 A | 2008-03-07 | 71% | 130.02d? | 2006-06-22 | 2008-03-07 | 447d? | 264d |  | C6 | 10232h | 4720h | eUPHBOOK | Claus Dietze (Giesecke & Devrient) | Rel-8 |  |  |  |
| 86 | 10.1 | Requirements for Contact Manager |  | 392d? | 2006-06-22 A | 2007-12-21 A | 100% |  | 2006-06-22 | 2007-12-21 | 392d? |  | finish no earlier than 2007-12-21 | C6 | 3136h | 3136h | eUPHBOOK-St1 | Claus Dietze (Giesecke & Devrient) | Rel-8 | 21.111 |  |  |
| 87 | 10.2 | External interface for eUPHBOOK |  | 220d? | 2007-05-07 A | 2008-03-07 | 80% | 44d? | 2007-05-07 | 2008-03-07 | 220d? | 264d | finish no earlier than 2008-03-07 | C6 | 1760h | 1408h | eUPHBOOK-Spec | Claus Dietze (Giesecke & Devrient) | Rel-8 | 31.xyz |  |  |
| 88 | 10.3 | Internal interface for eUPHBOOK |  | 220d? | 2007-05-07 A | 2008-03-07 | 10% | 198d? | 2007-05-07 | 2008-03-07 | 220d? | 264d | finish no earlier than 2008-03-07 | C6 | 1760h | 176h | eUPHBOOK-Spec | Claus Dietze (Giesecke & Devrient) | Rel-8 | 31.xyz |  |  |
| 89 | 10.4 | Deleted - Implementation of eUPHBOOK | milestone | 0d? | 2007-06-21 A | 2007-06-21 A | 100% |  | 2007-06-21 | 2007-06-21 | 0d? |  | start no earlier than 2007-06-21 | C6 |  |  | eUPHBOOK-St23 |  | Rel-8 | 31.102 |  |  |
| 90 | 11 | **Enhancements for VGCS Applications** |  | 528d? | 2006-03-15 A | 2008-03-21 | 82% | 92.75d? | 2006-03-15 | 2008-03-21 | 528d? | 254d |  | S1 | 17256h | 10895.6h | EVA | Amar Deol, Nortel Networks | Rel-8 | 42.068 | deola@nortel.com | Alain |
| 91 | 11.1 | SA1 aspects for EVA |  | 191d? | 2006-03-15 A | 2006-12-06 A | 100% |  | 2006-03-15 | 2006-12-06 | 191d? |  | finish no earlier than 2006-12-06 | S1 | 1528h | 1528h | EVA-s1 | Amar Deol, Nortel Networks | Rel-8 | 42.068 | deola@nortel.com | Alain |
| 92 | 11.2 | C1 aspects for EVA |  | 471d? | 2006-06-02 A | 2008-03-21 | 85% | 70.65d? | 2006-06-02 | 2008-03-21 | 471d? | 254d | finish no earlier than 2008-03-21 | C1 | 3768h | 3202.8h | EVA | Milan Patel (Nortel Networks) | Rel-8 | 43.068, 44.068 | milanpa@nortel.com | Andrijana |
| 93 | 11.3 | C4 aspects for EVA |  | 391d? | 2006-06-02 A | 2007-11-30 A | 100% |  | 2006-06-02 | 2007-11-30 | 391d? |  | finish no earlier than 2007-06-01 | C4 | 3128h | 3128h | EVA-c4 |  | Rel-8 | 29.002 |  | Kimmo |
| 94 | 11.4 | GERAN2 Aspects of EVA |  | 431d? | 2006-06-30 A | 2008-02-22 | 50% | 215.5d? | 2006-06-30 | 2008-02-22 | 431d? | 274d | finish no earlier than 2008-02-22 | G2 | 3448h | 1724h | EVA-EVGCSA | Frank Billenkamp (Nortel Networks) | Rel-8 | 44.018, 48.008 | frank.billenkamp@nortel.com | Gert |
| 95 | 11.5 | VGCS/VBS and GPRS Interactions |  | 145d? | 2007-09-03 A | 2008-03-21 A | 100% |  | 2007-09-03 | 2008-03-21 | 145d? |  | finish no earlier than 2008-03-21 | S1 | 1160h | 1160h | EVA-GPRS | Ling Liu, Huawei | Rel-8 | 42.068, 42.069 |  |  |
| 96 | 12 | **Multimedia Priority Service** |  | 527d? | 2006-06-08 A | 2008-06-14 | 54% | 242.57d? | 2006-06-08 | 2008-03-14 | 462d? | 194d |  | S1; C1; C3; C4 | 18732.8h | 5834.4h | PRIOR | Jim Garrahan (Telcordia) | Rel-8 | 22.153 | jgarraha@telcordia.com | Alain |
| 97 | 12.1 | Service Requirements for PRIOR |  | 387d? | 2006-06-08 A | 2007-11-30 A | 100% |  | 2006-06-08 | 2007-09-20 | 336d? |  | finish no earlier than 2007-11-30 | S1 | 3096h | 3096h | PRIOR-EMR | Jim Garrahan (Telcordia) | Rel-8 | 22.153 | jgarraha@telcordia.com | Alain |
| 98 | 12.2 | Stage 3 (CT1) for PRIOR |  | 401d? | 2006-12-01 A | 2008-06-14 | 42% | 233d? | 2006-12-01 | 2008-03-14 | 336d? | 194d | finish no earlier than 2008-06-14 | C1 | 3208h | 1344h | PRIOR-MM | Keith Drage, Alcatel-Lucent | Rel-8 | 24.229 | drage@Alcatel-Lucent.com | Andrijana |
| 99 | 12.3 | Stage 3 (CT3) for PRIOR |  | 126d? | 2007-09-21 | 2008-03-14 |  |  | 2007-09-21 | 2008-03-14 | 126d? | 259d | finish no earlier than 2008-03-14 | C3 | 1008h |  | PRIOR-MM |  | Rel-8 | 29.212, 29.213, 29.214, 29.163 |  | Seung Don |
| 100 | 12.4 | Stage 3 (CT4) for PRIOR |  | 126d? | 2007-09-21 A | 2008-03-14 | 5% | 119.7d? | 2007-09-21 | 2008-03-14 | 126d? | 259d | finish no earlier than 2008-03-14 | C4 | 1008h | 50.4h | PRIOR-MM |  | Rel-8 | 23.008, 29.228, 29.229 |  | Kimmo |
| 101 | 13 | **System enhancements for interconnection interfaces between two IMSs** |  | 468d? | 2006-08-16 A | 2008-05-30 | 32% | 317.36d? | 2006-08-16 | 2008-05-30 | 468d? | 204d |  | S2 | 9760h | 2194.36h | IMS_NNI | Steve Tsang-Kwong-U, Orange | Rel-8 |  |  |  |
| 102 | 13.1 | Stage 2 of IMS_NNI |  | 131d? | 2007-06-22 A | 2007-12-21 A | 100% |  | 2007-06-22 | 2007-12-21 | 131d? |  | finish no earlier than 2007-12-21 | S2 | 1048h | 1048h | IMS_NNI | Delphin Barankanira, Orange | Rel-8 |  |  |  |
| 103 | 13.2 | Deleted - Protocol impact of FBI for TISPAN R2 |  | 152d? | 2006-08-16 | 2007-03-15 |  |  | 2006-08-16 | 2007-03-15 | 152d? | 520d | finish no earlier than 2007-03-15 | C1 | 1216h |  | FBI2-TISP2-c1 |  | Rel-8 |  |  |  |
| 104 | 13.3 | IMS inter-operator service interconnection interface |  | 261d? | 2007-06-01 A | 2008-05-30 | 20% | 208.8d? | 2007-06-01 | 2008-05-30 | 261d? | 204d | finish no earlier than 2008-05-30 | C3 | 2088h | 417.6h | FBI2-IOPSI | Mauro Ficaccio (Telecom Italia) | Rel-8 | 29.865 | mauro.ficaccio@telecomitalia.it | MEREDITH, John M |
| 105 | 13.4 | Charging harmonization for NGN between 3GPP and ATIS-TMOC |  | 51d? | 2006-09-28 A | 2006-12-07 A | 100% |  | 2006-09-28 | 2006-12-07 | 51d? |  | finish no earlier than 2006-12-07 | S5 | 408h | 408h | FBI2-TISP2-CH | Amdocs | Rel-8 | 32.297 |  | Adrian |
| 106 | 13.5 | Deleted (never approved) - Stage 2 of FBI for TISPAN R2 - Rel 8 |  | 157d? | 2007-04-26 A | 2007-11-30 | 5% | 149.15d? | 2007-04-26 | 2007-11-30 | 157d? | 334d | start no earlier than 2007-04-26 | S2 | 1256h | 62.8h | FBI2-TISP2-s2 |  | Rel-8 |  |  |  |
| 107 | 14 | Deleted - IMS Enhancements Rel-8 |  | 75d? | 2007-09-03 A | 2007-12-14 | 83% | 13.08d? |  |  |  | 324d |  | S1 | 600h | 495.35h | IMS8 |  | Rel-8 |  |  |  |
| 108 | 15 | IMS Centralised Service Control |  | 75d? | 2007-09-03 A | 2007-12-14 | 80% | 15d? | 2007-09-03 | 2007-12-14 | 75d? | 324d | finish no earlier than 2007-12-14 | S1 | 600h | 480h | ICSRA | Randy Wohlert (AT&T) | Rel-8 | 22.101 |  |  |
| 109 | 16 | AS/MRFC stage 2 and 3 work |  | 218d? | 2007-11-14 | 2008-09-12 |  |  |  |  |  | 129d | finish no earlier than 2008-09-12 | C1 | 1744h |  | MRFC | Mark Syrett (Hewlett-Packard) | Rel-8 | 23.218, 24.229, 24.147, 24.247 |  | Andrijana |

Notes:
- 86: C6-43: Name Changed to Requirements for Contact Manager. Expected completion updated from CT#34 to CT#35.
- 87: New TS 31.xyz to be produced
- 88: Created at CT#37
- 92: Not reviewed at WG, directly from CT#37
- 93: CT4#32: Crs are presented and in principle agreed, waiting for the approval of stage2...
- 95: is this a one-CR WI?
- 96: Created by MCC to group 320023 (Stage 1) and 340012 (Stage 3) wrongly shown as idependent Features
- 97: Friday check
- 98: "CT1" corrected into "C1"
- 101: Name changed from "System enhancements for TISPAN Rel2" at SA36
- 103: To be reviewed in CT1
- 104: CP-36: WI approved. C3-36: draft 29.865 advanced.
- 105: 09/2006 SA#33 WID approved
- 106: It might be more appropriate to introduce the individual functions instead of a global title. SA2 WID expected at SA#36
- 107: Created by SA1 Chair and MCC to group all the IMS-related enhancements
- 109: CT1-50: C1-073183

| ID | WBS | Task | Duration | Start | Finish | Complete | Remaining | Baseline start | Baseline finish | Baseline duration | Total slack | Constraint | Resources | Work | Actual work | Text1 | Text6 | Text3 | Text4 | Text8 | Text5 |
| --- | --- | --- | --- | --- | --- | --- | --- | --- | --- | --- | --- | --- | --- | --- | --- | --- | --- | --- | --- | --- | --- |
| 110 | 17 | **IMS Multimedia Telephony and Supplementary Services** | 456d? | 2007-05-02 A | 2009-01-28 | 8% | 418.5d? |  |  |  | 31d |  | C1; C3; S1 | 37192h | 1544.27h | IMSTSS | Rel-8 |  |  |  |  |
| 111 | 17.1 | **General aspects of IMS Sup Services** | 75d? | 2007-09-03 A | 2007-12-14 | 78% | 16.81d? |  |  |  | 324d |  | S1; C1; C3; S5 | 1528h | 540h | IMSSS-Gal | Rel-8 |  |  |  |  |
| 112 | 17.1.1 | Service and Capability for Core IMS - inclusion of TISPAN requirements | 75d? | 2007-09-03 A | 2007-12-14 | 90% | 7.5d? | 2007-09-03 | 2007-12-14 | 75d? | 324d | finish no earlier than 2007-12-14 | S1 | 600h | 540h | TISCAPR8 | Rel-8 | 22.228, 22.115, 22.101 | Susana Sabater (Ericsson) |  |  |
| 113 | 17.1.2 | Documentation of TISPAN R1 and R2 in CT1 | 4d? | 2007-11-28 | 2007-12-03 |  |  |  |  |  | 333d | start no earlier than 2007-11-28 | C1 | 32h |  | REDOC_TIS-C1 | Rel-8 |  |  |  |  |
| 114 | 17.1.3 | Documentation of TISPAN R1 and R2 in CT3 | 4d? | 2007-11-28 | 2007-12-03 |  |  |  |  |  | 333d | start no earlier than 2007-11-28 | C3 | 32h |  | REDOC_TIS-C3 | Rel-8 |  |  |  |  |
| 115 | 17.1.4 | Documentation of TISPAN R1 and R2 in CT4 | 4d? | 2007-11-28 | 2007-12-03 |  |  |  |  |  | 333d | start no earlier than 2007-11-28 | C4 | 32h |  | REDOC_TIS-C4 | Rel-8 |  |  |  |  |
| 116 | 17.2 | **IMS Multimedia Telephony Service** | 328d? | 2007-09-10 A | 2008-12-10 | 21% | 258.78d? |  |  |  | 66d |  | S1; S5 | 6672h | 520h | IMS-MMTel | Rel-8 |  |  |  |  |
| 117 | 17.2.1 | Merging TISPAN MMTel [requirements] for Common IMS | 65d? | 2007-09-10 A | 2007-12-07 A | 100% |  | 2007-09-10 | 2007-12-07 | 65d? |  | finish no earlier than 2007-12-07 | S1 | 520h | 520h | TISMMTELR8 | Rel-8 | 22.173 | Joerg Swetina (NSN) |  |  |
| 118 | 17.2.2 | MMTel and Supplementary Services Charging | 243d? | 2008-01-07 | 2008-12-10 |  |  | 2005-09-02 | 2008-12-15 | 857d? | 66d | finish no earlier than 2008-12-10 | S5 | 1944h |  | MMTel-CH | Rel-8 | new 32.27x, 32.298/299 | ALU |  |  |
| 119 | 17.3 | **Call Completion on Busy Subscriber (CCBS)/Call Completion on Non-Reachable (CCNR) on IMS** | 304d? | 2007-05-02 | 2008-06-30 |  |  |  |  |  | 183d |  | C1; C3 | 9728h |  | IMSTSS-CConIMS | Rel-8 | 29.163, 24.229, 24.173 | Martin Hülsemann (Deutsche Telekom) | Andrijana |  |
| 120 | 17.3.1 | Stage 3 (CT1) of CConIMS | 304d? | 2007-05-02 | 2008-06-30 |  |  |  |  |  | 183d | finish no earlier than 2008-06-30 | C1 | 2432h |  | IMSTSS-CConIMS | Rel-8 | 29.163, 24.229, 24.173 | Martin Hülsemann (Deutsche Telekom) | Andrijana |  |
| 121 | 17.3.2 | Stage 3 (CT3) of CConIMS | 304d? | 2007-05-02 | 2008-06-30 |  |  |  |  |  | 183d | finish no earlier than 2008-06-30 | C3 | 2432h |  | IMSTSS-CConIMS | Rel-8 | 29.163, 24.229, 24.173 | Martin Hülsemann (Deutsche Telekom) | Andrijana |  |
| 122 | 17.4 | **Communication Wait on IMS** | 304d? | 2007-11-30 | 2009-01-28 |  |  |  |  |  | 31d |  | C1; C3 | 9728h |  | IMSTSS-CWonIMS | Rel-8 | 29.163, 24.229, 24.173 | Martin Hülsemann (Deutsche Telekom) | Andrijana |  |
| 123 | 17.4.1 | Stage 3 (CT1) of CWonIMS | 304d? | 2007-11-30 | 2009-01-28 |  |  |  |  |  | 31d | start no earlier than 2007-11-30 | C1 | 2432h |  | IMSTSS-CWonIMS | Rel-8 | 29.163, 24.229, 24.173 | Martin Hülsemann (Deutsche Telekom) | Andrijana |  |
| 124 | 17.4.2 | Stage 3 (CT3) of CWonIMS | 304d? | 2007-11-30 | 2009-01-28 |  |  |  |  |  | 31d | start no earlier than 2007-11-30 | C3 | 2432h |  | IMSTSS-CWonIMS | Rel-8 | 29.163, 24.229, 24.173 | Martin Hülsemann (Deutsche Telekom) | Andrijana |  |
| 125 | 18 | **MGCF interworking between User-to-User Signaling (UUS) and SIP** | 152d? | 2007-11-30 | 2008-06-30 |  |  |  |  |  | 183d |  | C1; C3 | 4864h |  | UUSIW | Rel-8 | 29.163, 24.279, 24.229 | YANG, Lili (Huawei) | Kimmo |  |
| 126 | 18.1 | Stage 3 (CT1) of UUSIW | 152d? | 2007-11-30 | 2008-06-30 |  |  |  |  |  | 183d | start no earlier than 2007-11-30 | C1 | 1216h |  | UUSIW | Rel-8 | 29.163, 24.279, 24.229 | YANG, Lili (Huawei) | Kimmo |  |
| 127 | 18.2 | Stage 3 (CT3) of UUSIW | 152d? | 2007-11-30 | 2008-06-30 |  |  |  |  |  | 183d | start no earlier than 2007-11-30 | C3 | 1216h |  | UUSIW | Rel-8 | 29.163, 24.279, 24.229 | YANG, Lili (Huawei) | Kimmo |  |
| 128 | 19 | **Support of Overlap signalling** | 126d? | 2007-11-30 | 2008-05-23 |  |  |  |  |  | 209d |  | C3 | 3024h |  | Overlap | Rel-8 | 29.163, 24.229, 29.228, 29.229 | JESSKE, Roland (Deutsche Telekom) | MEREDITH, John |  |
| 129 | 19.1 | CT1 aspects of overlap | 126d? | 2007-11-30 | 2008-05-23 |  |  |  |  |  | 209d | finish no earlier than 2008-05-23 | C1 | 1008h |  | Overlap-C1 | Rel-8 | 29.163, 24.229, 29.228, 29.229 | JESSKE, Roland (Deutsche Telekom) | MEREDITH, John |  |
| 130 | 19.2 | CT3 aspects of Overlap | 126d? | 2007-11-30 | 2008-05-23 |  |  |  |  |  | 209d | finish no earlier than 2008-05-23 | C3 | 1008h |  | Overlap-C3 | Rel-8 | 29.163, 24.229, 29.228, 29.229 | JESSKE, Roland (Deutsche Telekom) | MEREDITH, John |  |
| 131 | 20 | Maintenance of TISPAN R1 | 233d? | 2007-11-09 A | 2008-09-30 A | 100% |  |  |  |  |  | start no earlier than 2007-11-09 | C1; C3; C4 | 5592h | 5592h | MAINT_R1 | Rel-8 | 24.229, 24.127, 29.162, 29.163, 29.228, 29.229, 24.xxx | LEIS, Peter (Nokia Siemens Networks) | Kimmo |  |
| 132 | 21 | Maintenance of TISPAN R2 | 233d? | 2007-11-09 A | 2008-09-30 A | 100% |  |  |  |  |  | start no earlier than 2007-11-09 | C1; C3; C4 | 5592h | 5592h | MAINT_R2 | Rel-8 | 24.229, 24.127, 29.162, 29.163, 29.228, 29.229, 24.xxx | LEIS, Peter (Nokia Siemens Networks) | Kimmo |  |
| 133 | 22 | **IMS Service Brokering enhancements** | 69d? | 2005-12-07 A | 2006-03-13 A | 100% |  | 2005-12-07 | 2006-03-13 | 69d? |  |  | S1 | 1104h | 1104h | ISB | Rel-8 | 22.228 | John-Luc Bakker (Telcordia) | Alain | jbakker@telcordia.com |
| 134 | 22.1 | Stage 1 of ISB | 69d? | 2005-12-07 A | 2006-03-13 A | 100% |  | 2005-12-07 | 2006-03-13 | 69d? |  | finish no earlier than 2006-03-13 | S1 | 552h | 552h | ISB-s1 | Rel-8 | 22.228 | John-Luc Bakker (Telcordia) | Alain | jbakker@telcordia.com |

Notes:
- 118: 12/07 SA#38 WID Approval
- 119: C1-50: C1-073083/C3-071084
- 120: C1-50: C1-073083/C3-071084
- 121: C1-50: C1-073083/C3-071084
- 122: C1-50: C1-073084/C3-071085
- 123: C1-50: C1-073084/C3-071085
- 124: C1-50: C1-073084/C3-071085
- 125: C3-46: WID in C1-073199/ C3-071126
- 126: C3-46: WID in C1-073199/ C3-071126
- 127: C3-46: WID in C1-073199/ C3-071126
- 128: C3-46: WID in C1-073126 / C3-071127 /C4-072008.
- 129: C3-46: WID in C1-073126 / C3-071127 /C4-072008.
- 130: C3-46: WID in C1-073126 / C3-071127 /C4-072008.
- 131: C3-46: WID in C1-073189 / C3-071114 / C4-072032.
- 132: C3-46: WID in C1-073189 / C3-071114 / C4-072032.

| ID | WBS | Task | Duration | Start | Finish | Complete | Remaining | Baseline start | Baseline finish | Baseline duration | Total slack | Constraint | Resources | Work | Actual work | Text1 | Text3 | Text4 | Text6 | Text8 | Text5 |
| --- | --- | --- | --- | --- | --- | --- | --- | --- | --- | --- | --- | --- | --- | --- | --- | --- | --- | --- | --- | --- | --- |
| 135 | 23 | **Security Enhancements for IMS** | 402d? | 2007-03-01 A | 2008-09-12 | 18% | 328.88d? | 2007-03-01 | 2008-03-14 | 272d? | 129d |  | S3 | 8360h | 1520.66h | IMS-Sec | 33.203, 33.828, 33.803 | Bengt Sahlin (Ericsson) | Rel-8 | Dioniso |  |
| 136 | 23.1 | SA3 aspects of IMSSec | 272d? | 2007-03-01 A | 2008-03-14 | 43% | 155.04d? |  |  |  | 259d | start no earlier than 2007-03-01 | S3 | 2176h | 935.68h | IMS-Sec | 33.203, 33.828, 33.803 | Bengt Sahlin (Ericsson) | Rel-8 | Dioniso |  |
| 137 | 23.2 | NASS Bundled Authentication | 218d? | 2007-11-14 | 2008-09-12 |  |  |  |  |  | 129d | start no earlier than 2007-11-14 | C1 | 1744h |  | NBA | 24.229 |  | Rel-8 | Andrijana |  |
| 138 | 23.3 | NASS Bundled Authentication - CT4 part | 153d? | 2007-11-14 | 2008-06-13 |  |  |  |  |  | 194d | start no earlier than 2007-11-14 | C4 | 1224h |  | NBA-CT4 | 29.229, 29.228, 23.008 |  | Rel-8 |  |  |
| 139 | 24 | IMS System enhancements for corporate network access | 256d? | 2007-06-22 A | 2008-06-13 | 10% | 230.4d? | 2007-06-22 | 2007-12-21 | 131d? | 194d | finish no earlier than 2008-06-13 | S2 | 2048h | 204.8h | IMS_Corp |  | Delphin Barankanira, Orange | Rel-8 |  |  |
| 140 | 25 | **IMS Enhancements for support of Packet Cable access** | 398d? | 2006-12-06 A | 2008-06-15 | 67% | 133.13d? | 2006-12-06 | 2007-12-20 | 272d? | 194d |  | S2 | 26912h | 13790.6h | PktCbl |  |  | Rel-8 | Maurice |  |
| 141 | 25.1 | **IMS Enhancements for Security Requirements in Support of Cable Deployments** | 333d? | 2006-12-06 A | 2008-03-15 | 77% | 75.14d? | 2006-12-06 | 2007-12-20 | 272d? | 259d |  | S3 | 10960h | 6424h | PktCbl-Sec | 33.203, 33.210, 33.220, 24.229 | Steve Dotson (Cablelabs) | Rel-8 | Dioniso | s.dotson@cablelabs.com |
| 142 | 25.1.1 | S3 Aspects of PktCbl-Sec | 272d? | 2006-12-06 A | 2007-12-20 A | 100% |  | 2006-12-06 | 2007-12-20 | 272d? |  | finish no earlier than 2007-12-20 | S3 | 2176h | 2176h | PktCbl-Sec | 33.203, 33.210, 33.220, 24.229 | Steve Dotson (Cablelabs) | Rel-8 | Dioniso | s.dotson@cablelabs.com |
| 143 | 25.1.2 | CT1 Aspects of PktCbl-Sec | 255d? | 2007-03-26 A | 2008-03-15 | 28% | 183d? | 2007-03-26 | 2007-11-30 | 180d? | 259d | finish no earlier than 2008-03-15 | C1 | 2040h | 576h | PktCbl-Sec | 24.229, 24.109 | David Hancock (CableLabs) | Rel-8 | Andrijana | D.Hancock@ CableLabs.com |
| 144 | 25.1.3 | CT3 Aspects of PktCbl-Sec | 255d? | 2007-03-26 A | 2008-03-15 A | 100% |  | 2007-03-26 | 2007-11-30 | 180d? |  | finish no earlier than 2008-03-15 | C3 | 2040h | 2040h | PktCbl-Sec | 24.229, 24.109 | David Hancock (CableLabs) | Rel-8 |  | D.Hancock@ CableLabs.com |
| 145 | 25.1.4 | CT4 Aspects of PktCbl-Sec | 255d? | 2007-03-26 A | 2008-03-14 | 80% | 51d? | 2007-03-26 | 2007-11-30 | 180d? | 259d | finish no earlier than 2008-03-14 | C4 | 2040h | 1632h | PktCbl-Sec | 29.228, 29229, 23.008, | David Hancock (CableLabs) | Rel-8 | Kimmo | D.Hancock@ CableLabs.com |
| 146 | 25.2 | **IMS Enhancements for Cable Client Types and Deployment Models** | 355d? | 2007-02-05 A | 2008-06-15 | 40% | 211.94d? | 2007-02-05 | 2007-12-03 | 216d? | 194d |  | S2 | 7128h | 1930.35h | PktCbl-Deploy |  |  | Rel-8 |  |  |
| 147 | 25.2.1 | Architecture aspects of PktCbl-Deploy | 216d? | 2007-02-05 A | 2007-12-03 A | 100% |  | 2007-02-05 | 2007-12-03 | 216d? |  | finish no earlier than 2007-12-03 | S2 | 1728h | 1728h | PktCbl-Deploy |  |  | Rel-8 |  |  |
| 148 | 25.2.2 | CT1 aspects of PktCbl-Deploy | 320d? | 2007-03-26 | 2008-06-15 |  |  | 2007-03-26 | 2007-11-30 | 180d? | 194d | finish no earlier than 2008-06-15 | C1 | 2560h |  | PktCbl-Deploy | 24.229, 24167 | David Hancock (CableLabs) | Rel-8 | Andrijana | D.Hancock@ CableLabs.com |
| 149 | 25.3 | **IMS Inter-working Aspects in Support of Cable Regulatory requirements** | 290d? | 2007-02-05 A | 2008-03-15 | 73% | 77.57d? | 2007-02-05 | 2007-11-30 | 215d? | 259d |  | S2 | 5640h | 3317.29h | PktCbl-Intw | 23.228 | Bernie McKibben (CableLabs) | Rel-8 | Maurice | B.McKibben@CableLabs.com |
| 150 | 25.3.1 | Architecture aspects of PktCbl-Interwork | 160d? | 2007-02-05 A | 2007-09-14 A | 100% |  | 2007-02-05 | 2007-09-14 | 160d? |  | start no earlier than 2007-02-05 | S2 | 1280h | 1280h | PktCbl-Intw | 23.228 | Bernie McKibben (CableLabs) | Rel-8 | Maurice | B.McKibben@CableLabs.com |
| 151 | 25.3.2 | CT1 aspects of PktCbl-Interwork | 255d? | 2007-03-26 A | 2008-03-15 | 56% | 111d? | 2007-03-26 | 2007-11-30 | 180d? | 259d | finish no earlier than 2008-03-15 | C1 | 2040h | 1152h | PktCbl-Intw | 24.229 | David Hancock (CableLabs) | Rel-8 | Andrijana | D.Hancock@ CableLabs.com |
| 152 | 26 | **eCall Data Transfer** | 307d? | 2006-09-28 A | 2007-11-30 | 80% | 61.4d? | 2006-09-28 | 2006-12-07 | 51d? | 334d |  | S1 | 4912h | 3929.6h | EData | 22.101, 22.105 | Rhys Robinson (Airbiquity) | Rel-8 | Alain | rrobinson@airbiquity.com |
| 153 | 26.1 | eData Requirements | 307d? | 2006-09-28 A | 2007-11-30 | 80% | 61.4d? | 2006-09-28 | 2006-12-07 | 51d? | 334d | finish no earlier than 2006-12-07 | S1 | 2456h | 1964.8h | EData | 22.101, 22.105 | Rhys Robinson (Airbiquity) | Rel-8 | Alain | rrobinson@airbiquity.com |
| 154 | 27 | Local Charging Zone Requirements | 51d? | 2006-09-28 A | 2006-12-07 A | 100% |  | 2006-09-28 | 2006-12-07 | 51d? |  | finish no earlier than 2006-12-07 | S1 | 408h | 408h | LCZR | 22.115 | Hong Liu (China Mobile) | Rel-8 | Alain | liuhongyfw@chinamobile.com |
| 155 | 28 | Services Alignment and Migration | 323d? | 2006-12-06 A | 2008-02-29 | 80% | 64.6d? | 2006-12-06 | 2007-11-28 | 256d? | 269d | finish no earlier than 2008-02-29 | S1 | 2584h | 2067.2h | ServAl | 22.182 | Feng Lingjuan (China Mobile) | Rel-8 | Alain | fenglingjuan@chinamobile.com |
| 156 | 29 | Value Added Services for Short Message Service | 140d? | 2007-09-10 A | 2008-03-21 | 70% | 42d? | 2007-09-10 | 2008-03-21 | 140d? | 254d | finish no earlier than 2008-03-21 | S1 | 1120h | 784h | VAS4SMS | 22.142 | Wu Bin (China Mobile) | Rel-8 |  | wubin@chinamobile.com |
| 157 | 30 | **Customised Alerting Tone** | 264d? | 2006-12-06 A | 2007-12-10 A | 100% |  | 2006-12-06 | 2007-12-10 | 264d? |  |  | S1 | 4336h | 4336h | CAT | 22.182 | Feng Lingjuan (China Mobile) | Rel-8 | Alain | (fenglingjuan@chinamobile.com) |
| 158 | 30.1 | Stage 1 for CAT | 207d? | 2006-12-06 A | 2007-09-20 A | 100% |  | 2006-12-06 | 2007-09-20 | 207d? |  | start no earlier than 2006-12-06 | S1 | 1656h | 1656h | CAT | 22.182 | Feng Lingjuan (China Mobile) | Rel-8 | Alain | (fenglingjuan@chinamobile.com) |
| 159 | 30.2 | Customized multimedia information services - inclusion of TISPAN requirements | 71d? | 2007-09-03 A | 2007-12-10 A | 100% |  | 2007-09-03 | 2007-12-10 | 71d? |  | finish no earlier than 2007-12-10 | S1 | 568h | 568h | TISCMI | 22.182 | Peter Bleckert (Ericsson) | Rel-8 |  |  |
| 160 | 31 | I-WLAN Network Selection Principle | 1d? | 2007-09-03 A | 2007-09-03 A | 100% |  | 2007-09-03 | 2007-09-03 | 1d? |  |  | S1 | 8h | 8h | IWLANNSP | 22.234 | Chris Friel (O2) | Rel-8 | Alain | chris.friel@o2.com |

Notes:
- 135: WID approved at SP-36
- 136: WID approved at SP-36
- 143: Supporting Companies:
- 144: Added as 100% complete at CT#38
- 145: Supporting Companies:
- 148: Supporting Companies:
- 149: Supporting Companies: CableLabs, Nortel, Cisco, Samsung, Alcatel-Lucent, Siemens, Motorola, Hewlett-Packard, Ericsson
- 150: Supporting Companies: CableLabs, Nortel, Cisco, Samsung, Alcatel-Lucent, Siemens, Motorola, Hewlett-Packard, Ericsson
- 151: Supporting Companies:
- 153: SA4 related activity - to be checked
- 155: previous names were Services Alignment, Service Migration
- 157: Acronym changed from "CusAlert" to "CAT"

| ID | WBS | Task | Type | Duration | Start | Finish | Complete | Remaining | Baseline start | Baseline finish | Baseline duration | Total slack | Constraint | Resources | Work | Actual work | Text1 | Text4 | Text5 | Text6 | Text8 | Text7 |
| --- | --- | --- | --- | --- | --- | --- | --- | --- | --- | --- | --- | --- | --- | --- | --- | --- | --- | --- | --- | --- | --- | --- |
| 161 | 32 | **Interworking Wireless LAN Mobility** |  | 196d? | 2007-09-14 A | 2008-06-13 | 25% | 147d? | 2007-01-01 | 2008-07-11 | 400d? | 194d |  | S2 | 3136h | 784h | IWLAN_Mob | Xiaobao Chen, Orange | xiaobao.chen@orange-ftgroup.com | Rel-8 | Maurice |  |
| 162 | 32.1 | Stage 2: Interworking Wireless LAN Mobility |  | 196d? | 2007-09-14 A | 2008-06-13 | 25% | 147d? |  |  |  | 194d | start no earlier than 2007-09-14 | S2 | 1568h | 392h | IWLAN_Mob |  |  | Rel-8 |  |  |
| 163 | 33 | **Service-Level Interworking for Messaging Services** |  | 249d? | 2007-03-26 A | 2008-03-07 | 80% | 49.8d? | 2007-03-26 | 2007-12-24 | 195d? | 264d |  | S1 | 3808h | 2508.8h | MESSIW | Liu Ling (Huawei); Duan Xiaoqin (Huawei) | ling.liu@huawei.com; duanxiaoqin@huawei.com | Rel-8 | Alain |  |
| 164 | 33.1 | Stage 1 aspects of MESSIW | milestone | 0d? | 2007-03-26 A | 2007-03-26 A | 100% |  | 2007-03-26 | 2007-03-26 | 0d? |  | finish no earlier than 2007-12-01 | S1 |  |  | MESSIW-St1 | Liu Ling (Huawei) | ling.liu@huawei.com | Rel-8 | Alain |  |
| 165 | 33.2 | Stage 2 aspects of MESSIW |  | 227d? | 2007-04-26 A | 2008-03-07 | 80% | 45.4d? | 2007-04-26 | 2007-12-24 | 173d? | 264d | finish no earlier than 2008-03-07 | S2 | 1816h | 1452.8h | MESSIW-St2 | Patrice Hede (Huawei) | patrice.hede@huawei.com | Rel-8 | Maurice |  |
| 166 | 34 | **OAM&P 8** |  | 581d? | 2006-09-22 A | 2008-12-12 | 25% | 433d? | 2005-09-02 | 2008-12-15 | 857d? | 64d |  | S5 | 22497.5h | 4995.2h | OAM8 |  |  | Rel-8 | Adrian |  |
| 167 | 34.1 | Telecom Management Methodology |  | 396d? | 2007-06-07 A | 2008-12-11 | 50% | 198d? | 2005-09-02 | 2008-12-15 | 857d? | 65d | finish no earlier than 2008-12-11 | S5 | 3168h | 1584h |  | Ericsson |  | Rel-8 |  |  |
| 168 | 34.2 | Advanced Alarming on Itf-N (Study + Implementation) |  | 196d? | 2007-06-07 A | 2008-03-06 | 50% | 98d? | 2005-09-02 | 2007-12-14 | 596d? | 265d | finish no earlier than 2008-03-06 | S5 | 1568h | 784h |  | NSN |  | Rel-8 |  |  |
| 169 | 34.3 | CN CS Bearer Transport Network (BTN) relative NRM |  | 196d? | 2007-06-07 A | 2008-03-06 | 30% | 137.2d? | 2005-09-02 | 2007-12-14 | 596d? | 265d | finish no earlier than 2008-03-06 | S5 | 1568h | 470.4h |  | China Mobile |  | Rel-8 |  |  |
| 170 | 34.4 | IP bearer network Performance measurement definitions |  | 196d? | 2007-06-07 A | 2008-03-06 | 40% | 117.6d? | 2005-09-02 | 2007-12-14 | 596d? | 265d | finish no earlier than 2008-03-06 | S5 | 1568h | 627.2h |  | China Mobile |  | Rel-8 |  |  |
| 171 | 34.5 | HSUPA performance measurements |  | 196d? | 2007-06-07 A | 2008-03-06 | 30% | 137.2d? | 2007-06-07 | 2008-03-06 | 196d? | 265d | finish no earlier than 2008-03-06 | S5 | 1568h | 470.4h |  | China Mobile |  | Rel-8 |  |  |
| 172 | 34.6 | Key Performance Indicators (KPIs) for UMTS/GERAN |  | 331d? | 2007-06-07 A | 2008-09-11 | 20% | 264.8d? | 2007-06-07 | 2008-03-06 | 196d? | 130d | finish no earlier than 2008-09-11 | S5 | 2648h | 529.6h |  | China Mobile |  | Rel-8 |  |  |
| 173 | 34.7 | Subscriber and Equipment Trace for eUTRAN and EPC |  | 259d? | 2007-09-17 A | 2008-09-11 | 20% | 207.2d? |  |  |  | 130d | finish no earlier than 2008-09-11 | S5 | 2072h | 414.4h |  | Ericsson |  | Rel-8 |  |  |
| 174 | 34.8 | End point modelling for reference point |  | 124d? | 2007-09-17 A | 2008-03-06 | 10% | 111.6d? |  |  |  | 265d | start no earlier than 2007-09-17 | S5 | 992h | 99.2h |  | Motorola |  | Rel-8 |  |  |
| 175 | 34.9 | Service Level Tracing in IMS |  | 555.18d? | 2006-09-22 A | 2008-12-12 |  | 555.18d? | 2006-09-22 | 2008-04-10 | 379.14d? | 64d | finish no earlier than 2008-12-15 | C1 | 4441.47h |  | OAM7-Trace | Jari Jansson, Nokia | jari.jansson@nokia.com | Rel-8 | Andrijana |  |
| 176 | 34.10 | Deleted - Network Infrstructure Management 8 | milestone | 0d? | 2007-07-13 A | 2007-07-13 A | 100% |  | 2007-07-13 | 2007-07-13 | 0d? |  | finish no earlier than 2007-07-13 | S5 |  |  |  |  |  | Rel-8 | Adrian |  |
| 177 | 34.11 | Deleted - Performance Management 8 |  | 1d? | 2007-07-13 A | 2007-07-13 A | 100% |  | 2007-07-13 | 2007-07-13 | 1d? |  |  | S5 | 8h | 8h |  |  |  | Rel-8 | Adrian |  |
| 178 | 34.12 | Deleted - Trace Management 8 |  | 1d? | 2007-06-22 A | 2007-06-22 A | 100% |  | 2007-06-22 | 2007-06-22 | 1d? |  | start no earlier than 2007-06-22 | S5 | 8h | 8h |  |  |  | Rel-8 |  |  |
| 179 | 35 | **Registration in Densely-populated area** |  | 330d? | 2007-03-12 A | 2008-06-13 | 41% | 193.9d? | 2007-03-12 | 2007-12-07 | 195d? | 194d |  | S1 | 4184h | 665.6h | RED | Tsuyoshi Takakura (NTT DoCoMo Inc.) | takakurat@s1.nttdocomo.co.jp | Rel-8 | Alain |  |
| 180 | 35.1 | Stage 1 for RED |  | 4d? | 2007-03-12 A | 2007-03-15 A | 100% |  | 2007-03-12 | 2007-03-15 | 4d? |  | start no earlier than 2007-03-12 | S1 | 32h | 32h | RED | Tsuyoshi Takakura (NTT DoCoMo Inc.) | takakurat@s1.nttdocomo.co.jp | Rel-8 | Alain |  |
| 181 | 35.2 | Stage2 for Registration in Densely-populated area (RED) |  | 189d? | 2007-09-25 A | 2008-06-13 | 40% | 113.4d? | 2007-09-25 | 2007-12-07 | 54d? | 194d | finish no earlier than 2008-06-13 | S2 | 1512h | 604.8h | RED-St2 | Itsuma Tanaka (NTT DoCoMo Inc.) | tanakai@nttdocomo.co.jp | Rel-8 | Maurice |  |
| 182 | 36 | Lawful Interception in the 3GPP Rel-8 |  | 265d? | 2007-03-12 A | 2008-03-14 | 20% | 212d? | 2007-03-12 | 2008-03-14 | 265d? | 259d | finish no earlier than 2008-03-14 | S3 | 2120h | 424h | LI8 | Berthold Wilhelm (BMWi/BNetzA) | berthold.wilhelm@bnetza.de | Rel-8 | Dioniso |  |
| 183 | 37 | **Rel-8 Improvements of the Radio Interface** |  | 314d? | 2007-03-05 A | 2008-05-15 | 33% | 209.56d? | 2007-03-05 | 2008-05-15 | 314d? | 215d |  | RP | 11408h | 3820h | RInImp8 |  |  | Rel-8 | Claude |  |
| 184 | 37.1 | UMTS 1500 MHz |  | 140d? | 2007-03-05 A | 2007-09-14 A | 100% |  | 2007-03-05 | 2007-09-14 | 140d? |  | finish no earlier than 2007-09-14 | R4 | 1120h | 1120h | RInImp8-UMTS1500 | Takehiro Nakamura | NTT DoCoMo | Rel-8 | Claude | TSG |
| 185 | 37.2 | UMTS 700 MHz |  | 215d? | 2007-03-05 A | 2007-12-28 | 25% | 161.25d? | 2007-03-05 | 2007-12-28 | 215d? | 314d | start no earlier than 2007-03-05 | R4 | 1720h | 430h | RInImp8-UMTS700 | Tuomo Saynajakangas | Nokia | Rel-8 | Claude | TSG |
| 186 | 37.3 | UMTS 2300 MHz |  | 215d? | 2007-03-05 A | 2007-12-28 | 5% | 204.25d? | 2007-03-05 | 2007-12-28 | 215d? | 314d | start no earlier than 2007-03-05 | R4 | 1720h | 86h | RInImp8-UMTS2300 | Marc Grant | marc.grant@cingular.com | Rel-8 | Claude | TSG |
| 187 | 37.4 | Further Improved Minimum Performance Requirements for HSDPA UE (FDD) - Two-Branch Interference Cancellation |  | 215d? | 2007-03-05 A | 2007-12-28 | 80% | 43d? | 2007-03-05 | 2007-12-28 | 215d? | 314d | finish no earlier than 2007-12-28 | R4 | 1720h | 1376h | RInImp8-2BIC | Marc Grant, Cingular | marc.grant@cingular.com | Rel-8 | MCC_RAN |  |
| 188 | 37.5 | CS Voice Service over HSPA |  | 172d? | 2007-07-19 | 2008-03-14 |  |  | 2007-07-19 | 2008-03-14 | 172d? | 259d | start no earlier than 2007-07-19 | R2 | 1376h |  | RInImp8-CsHspa | Woonhee Hwang, Nokia Siemens Networks | woonhee.hwang@nsn.com | Rel-8 | MCC_RAN |  |
| 189 | 37.6 | Performance requirements for 15 code reception with 16QAM/QPSK |  | 175d? | 2007-09-14 | 2008-05-15 |  |  | 2007-09-14 | 2008-05-15 | 175d? | 215d | start no earlier than 2007-09-14 | R2 | 1400h |  | RInImp8-Hsdpa15codes | Tim Frost, Vodafone | tim.frost@vodafone.com | Rel-8 | MCC_RAN |  |

Notes:
- 161: Name changed before SA#38 (was "Mobility between 3GPP-WLAN Interworking and 3GPP Systems") / Text3: 23.xxx
- 163: WID updated by S2-57, Approved at SP-36 / Text3: 22.105, 22.340, 23.abc, TS 23.xyz (TBD)
- 164: Text3: 22.105, 22.340
- 165: WID updated by S2-57, Approved at SP-36. Rapporteur updated S2#59. TR for Information to SA#38 / Text3: 22.105, 22.340, 23.811
- 166: Created to encompass the Rel7 Work Tasks shifted to Rel8
- 167: Text3: new 32.155 , 32.153
- 168: Text3: new 32.121/2/3/5
- 169: Text3: new 32.74x
- 170: Text3: 32.321/2/3/5
- 171: Text3: 32.405
- 172: Text3: 32.405
- 173: Text3: 32.42x, 32.44x
- 174: Text3: 32.152, 32.62/3/4x, 32.73x
- 175: Cannot proceed without substancial IETF contribution / Text3: 24.229, 24.167, 29.228,29.229,29.163,29.332
- 176: Created to encompass the Rel7 Work Tasks shifted to Rel8
- 177: Created to encompass the Rel7 Work Tasks shifted to Rel8
- 178: Created to encompass the Rel7 Work Tasks shifted to Rel8
- 179: One CR at SA #35 / Text3: 22.101
- 180: One CR at SA #35 / Text3: 22.101
- 181: Approved as BB at SP-37 / Text3: 23.880
- 182: End date to be determined when Rel-8 frozen. / Text3: 33.106, 33.107, 33.108
- 184: Text3: TS25.101, TS25.104, TS25.133, TS25.141, TS25.331, TS25.942, TS25.306, TS25.307, TS34.121
- 185: Text3: TS25.101, TS25.104, TS25.133, TS25.141, TS25.331, TS25.942, TS25.306, TS25.307, TS34.121
- 186: Text3: TS25.101, TS25.104, TS25.133, TS25.141, TS25.331, TS25.942, TS25.306, TS25.307, TS34.121
- 188: Text3: 25.323, 25.331, 25.322
- 189: Text3: 25.101

| ID | WBS | Task | Type | Duration | Start | Finish | Complete | Remaining | Baseline start | Baseline finish | Baseline duration | Total slack | Constraint | Resources | Work | Actual work | Text1 | Text4 | Text5 | Text6 | Text8 | Text7 |
| --- | --- | --- | --- | --- | --- | --- | --- | --- | --- | --- | --- | --- | --- | --- | --- | --- | --- | --- | --- | --- | --- | --- |
| 190 | 38 | **Personal Network Management** |  | 835d? | 2005-07-11 A | 2008-09-19 | 52% | 398.34d? | 2005-07-11 | 2008-09-19 | 835d? | 124d |  | S1 | 18124.8h | 8781.45h | PNM | Armin Toepfer, Vodafone | armin.toepfer@vodafone.com | Rel-8 | Alain |  |
| 191 | 38.1 | Stage 1 of PNM |  | 276d? | 2005-07-11 A | 2006-07-31 A | 100% |  | 2005-07-11 | 2006-07-31 | 276d? |  | start no earlier than 2005-07-11 | S1 | 2208h | 2208h | PNM |  |  | Rel-8 | Alain |  |
| 192 | 38.2 | Deleted - Actual Requirements of PNM | milestone | 0d? | 2007-03-26 A | 2007-03-26 A | 100% |  | 2007-03-26 | 2007-03-26 | 0d? |  | finish no earlier than 2007-03-26 | C1 |  |  | PNM |  |  | Rel-8 |  |  |
| 193 | 38.3 | Stage 2 of PNM |  | 263d? | 2007-03-26 A | 2008-03-26 | 90% | 26.3d? | 2007-03-26 | 2008-03-26 | 263d? | 251d | finish no earlier than 2008-03-26 | C1 | 2104h | 1893.6h | PNM | Yang Lu (Vodafone) | yang.lu@vodafone.com | Rel-8 | Andrijana |  |
| 194 | 38.4 | **Stage 3 of PNM** |  | 390d? | 2007-03-26 A | 2008-09-19 | 17% | 323.92d? | 2007-03-26 | 2008-09-19 | 390d? | 124d |  | C1 | 7195.2h | 1219.21h | PNM | Yang Lu (Vodafone) | yang.lu@vodafone.com | Rel-8 | Andrijana |  |
| 195 | 38.4.1 | CT1 aspects of PNM |  | 390d? | 2007-03-26 A | 2008-09-19 | 25% | 292.5d? | 2007-03-26 | 2008-09-19 | 390d? | 124d | finish no earlier than 2008-09-19 | C1 | 3120h | 780h | PNM | Yang Lu (Vodafone) | yang.lu@vodafone.com | Rel-8 | Andrijana |  |
| 196 | 38.4.2 | CT4 aspects of PNM |  | 263d? | 2007-03-26 A | 2008-03-26 | 5% | 249.85d? | 2007-03-26 | 2008-03-26 | 263d? | 251d | start no earlier than 2007-03-26 | C4 | 2104h | 105.2h | PNM | Yang Lu, |  | Rel-8 |  |  |
| 197 | 39 | **Charging Management small Enhancements** |  | 715d? | 2006-03-16 A | 2008-12-10 | 48% | 368.91d? | 2006-05-08 | 2007-12-14 | 420d? | 66d |  | S5 | 14768h | 4566.27h | CH8 | Orange |  | Rel-8 | Adrian |  |
| 198 | 39.1 | Online charging correlation |  | 420d? | 2006-03-16 A | 2007-12-14 A | 100% |  | 2006-05-08 | 2007-12-14 | 420d? |  | finish no earlier than 2007-12-14 | S5 | 3360h | 3360h |  | Orange |  | Rel-8 |  |  |
| 199 | 39.2 | SMS online charging |  | 137d? | 2007-06-07 A | 2007-12-14 A | 100% |  | 2007-04-02 | 2007-09-12 | 118d? |  | finish no earlier than 2007-12-14 | S5 | 1096h | 1096h |  | Vodafone |  | Rel-8 |  |  |
| 200 | 39.3 | Add Interconnection Border Control Function (IBCF) to IMS Charging |  | 264d? | 2007-09-17 A | 2008-09-18 | 5% | 250.8d? |  |  |  | 125d | finish no earlier than 2008-09-18 | S5 | 2112h | 105.6h |  | ALU |  | Rel-8 |  |  |
| 201 | 39.4 | Advice of Charge (AoC) support in IMS Charging |  | 243d? | 2008-01-07 | 2008-12-10 |  |  | 2005-09-02 | 2008-12-15 | 857d? | 66d | finish no earlier than 2008-12-10 | S5 | 1944h |  |  | NSN |  | Rel-8 |  |  |
| 202 | 39.5 | WLAN Offline Charging |  | 114d? | 2008-01-07 | 2008-06-12 |  |  | 2005-09-02 | 2008-12-15 | 857d? | 195d | finish no earlier than 2008-06-12 | S5 | 912h |  |  | ALU |  | Rel-8 |  |  |
| 203 | 40 | **OSA Rel-8** |  | 336d? | 2007-08-23 A | 2008-12-04 | 25% | 251.91d? | 2007-08-23 | 2008-12-04 | 336d? | 70d |  | S1 | 15680h | 3667.52h | OSA8 | Orange |  | Rel-8 | Alain | TSG |
| 204 | 40.1 | OSA Stage 1 - Service Requirements |  | 74d? | 2007-08-23 A | 2007-12-04 A | 100% |  | 2007-08-23 | 2008-12-04 | 336d? |  | finish no earlier than 2007-12-04 | S1 | 592h | 592h | OSA8 |  |  | Rel-8 | Alain | TSG |
| 205 | 40.2 | OSA Stage 1 - NGN Service Requirement |  | 140d? | 2007-09-03 A | 2008-03-14 A | 100% |  | 2007-09-03 | 2008-03-14 | 140d? |  | finish no earlier than 2008-03-14 | S1 | 1120h | 1120h | OSA8 | Song Dong (Orange) |  | Rel-8 |  |  |
| 206 | 40.3 | **OSA Stage 2/3 enhancements** |  | 291d? | 2007-10-25 A | 2008-12-04 | 14% | 250.26d? | 2007-10-25 | 2008-12-04 | 291d? | 70d |  | C5 | 13968h | 1955.52h | OSA8 | Orange |  | Rel-8 | Adrian |  |
| 207 | 40.3.1 | Ensure Parlay-X composable with identity management frameworks, in particular Liberty Alliance |  | 291d? | 2007-10-25 | 2008-12-04 |  |  | 2007-10-25 | 2008-12-04 | 291d? | 70d | finish no earlier than 2008-12-04 | C5 | 2328h |  | OSA8 | AePONA |  | Rel-8 |  |  |
| 208 | 40.3.2 | Parlay-X Content Management web service (store/manage meta-data) |  | 291d? | 2007-10-25 | 2008-12-04 |  |  | 2007-10-25 | 2008-12-04 | 291d? | 70d | finish no earlier than 2008-12-04 | C5 | 2328h |  | OSA8 | ETRI |  | Rel-8 |  |  |
| 209 | 40.3.3 | Parlay-X Policy web service |  | 291d? | 2007-10-25 A | 2008-12-04 | 70% | 87.3d? | 2007-10-25 | 2008-12-04 | 291d? | 70d | finish no earlier than 2008-12-04 | C5 | 2328h | 1629.6h | OSA8 | ETRI |  | Rel-8 |  |  |
| 210 | 40.3.4 | Parlay-X Terminal status web service |  | 291d? | 2007-10-25 | 2008-12-04 |  |  | 2007-10-25 | 2008-12-04 | 291d? | 70d | finish no earlier than 2008-12-04 | C5 | 2328h |  | OSA8 | Orange |  | Rel-8 |  |  |
| 211 | 40.3.5 | Identify communication format used by a particular application |  | 291d? | 2007-10-25 | 2008-12-04 |  |  | 2007-10-25 | 2008-12-04 | 291d? | 70d | finish no earlier than 2008-12-04 | C5 | 2328h |  | OSA8 | AePONA |  | Rel-8 |  |  |
| 212 | 41 | **Rel-8 RAN improvements** |  | 335d? | 2007-06-04 A | 2008-09-12 | 4% | 321.87d? | 2007-06-04 | 2008-09-12 | 335d? | 129d |  | RP | 10888h | 426.61h | RANimp |  |  | Rel-8 |  |  |
| 213 | 41.1 | Combination of 64QAM and MIMO for HSDPA (FDD) |  | 201d? | 2007-06-04 A | 2008-03-10 | 20% | 160.8d? | 2007-06-04 | 2008-03-10 | 201d? | 263d | finish no earlier than 2008-03-10 | R1 | 1608h | 321.6h | RANimp-64QamMimoHsdpa | Johan Bergman, Ericsson | Johan.Bergman@ericsson.com | Rel-8 | MCC_RAN |  |
| 214 | 41.2 | Improved L2 for uplink |  | 127d? | 2007-09-14 | 2008-03-10 |  |  | 2007-09-14 | 2008-03-10 | 127d? | 263d | start no earlier than 2007-09-14 | R2 | 1016h |  | RANimp-UplinkL2dataRates | Janne Peisa, Ericsson | Janne.Peisa@ericsson.com | Rel-8 | MCC_RAN |  |
| 215 | 41.3 | Enhanced Uplink for CELL_FACH State in FDD |  | 175d? | 2007-09-14 | 2008-05-15 |  |  | 2007-09-14 | 2008-05-15 | 175d? | 215d | start no earlier than 2007-09-14 | R2 | 1400h |  | RANimp-UplinkEnhState | Markus Wimmer, Nokia Siemens Networks | markus.wimmer@nsn.com | Rel-8 | MCC_RAN |  |
| 216 | 41.4 | Enhanced UE DRX for FDD |  | 261d? | 2007-09-14 | 2008-09-12 |  |  | 2007-09-14 | 2008-09-12 | 261d? | 129d | finish no earlier than 2008-09-12 | R2 | 2088h |  | RANimp-DRX | Luís Barreto, Nokia | luis.barreto@nokia.com | Rel-8 | MCC_RAN |  |
| 217 | 41.5 | Enhancements for SRNS Relocation Procedure |  | 131d? | 2007-09-14 | 2008-03-14 |  |  | 2007-09-14 | 2008-03-14 | 131d? | 259d | finish no earlier than 2008-03-14 | R3 | 1048h |  | RANimp-SrnsReloc | Masatoshi Nakamata, Nokia Siemens Networks | masatoshi.nakamata@nsn.com | Rel-8 | MCC_RAN |  |
| 218 | 41.6 | Enhancements for FDD HSPA Evolution |  | 131d? | 2007-09-14 | 2008-03-14 |  |  | 2007-09-14 | 2008-03-14 | 131d? | 259d | finish no earlier than 2008-03-14 | R3 | 1048h |  | RANimp-HSPAEvo | Masatoshi Nakamata, Nokia Siemens Networks | masatoshi.nakamata@nsn.com | Rel-8 | MCC_RAN |  |

Notes:
- 190: Moved from FS section Feb 06. SP-33: Create new section to capture the PNM stage 2 aspects and identify any impacts to existing stage 2 specifications. S2 added as secondary responsibility
- 191: Moved from FS section Feb 06: SP-33: Create new section to capture the PNM stage 2 aspects and identify any impacts to existing stage 2 specifications. / Text3: 22.259, 23.818
- 193: Text3: 23.259
- 194: Moved from FS section Feb 06: SP-33: Create new section to capture the PNM stage 2 aspects and identify any impacts to existing stage 2 specifications.
- 195: Text3: 24.229, 24.259
- 196: Text3: 23.008, 23.018, 29.002, 29.328, 29.329
- 197: Text3: 32.2xy
- 198: WID approved SA#35 / Text3: 32.240, 32.296
- 199: Text3: new 32.274, CR 32.240 / 299/ 298
- 200: Text3: 32.240/260/298/299
- 201: 12/07 SA#38 WID Approval / Text3: new 32.27x, 32.240/260/296/298/299
- 202: 12/07 SA#38 WID Approval / Text3: 32.252/298/299
- 204: az: WID URL corrected / Text3: 22.127
- 205: Text3: 22.127
- 206: Text3: 23.198, 29.198/9
- 207: Text3: 29.199-xy
- 208: Text3: 29.199-NEW
- 209: Text3: 29.199-22
- 210: Text3: 29.199-NEW
- 211: Text3: 29.199-xy
- 213: Text3: 25.308,25.211,25.212,25.213,25.306,25.331,25.433,25.435,25.423,25.425,25.101,25.104,25.141
- 214: Text3: 25.319, 25.301, 25.306, 25.321, 25.331, 25.433, 25.435, 25.423, 25.425, 25.427
- 215: Text3: 25.309, 25.211, 25.214, 25.321, 25.331, 25.423, 25.433
- 216: Text3: 25.306, 25.308, 25.321, 25.331, 25.423
- 217: Text3: 25.306, 25.308, 25.321, 25.331, 25.423, 25.433, 25.214, 25.133
- 218: Text3: 25.423, 25.427, 25.433

| ID | WBS | Task | Type | Duration | Start | Finish | Complete | Remaining | Baseline start | Baseline finish | Baseline duration | Total slack | Constraint | Resources | Work | Actual work | Text1 | Text4 | Text5 | Text6 | Text8 | Text3 | Text7 | Text12 |
| --- | --- | --- | --- | --- | --- | --- | --- | --- | --- | --- | --- | --- | --- | --- | --- | --- | --- | --- | --- | --- | --- | --- | --- | --- |
| 219 | 42 | **Support of (G)MSC-S – (G)MSC-S Nc Interface based on the SIP-I protocol** |  | 266d? | 2007-09-14 A | 2008-09-19 | 24% | 201.27d? | 2007-09-14 | 2008-09-19 | 266d? | 124d |  | C4 | 8512h | 2071.25h | SIP_Nc | David Hutton (Vodafone Group) | David.Hutton@VODAFONE.COM | Rel-8 | Kimmo |  |  |  |
| 220 | 42.1 | SIP-I based circuit-switched core network; Stage 2 |  | 266d? | 2007-09-14 A | 2008-09-19 | 50% | 133d? | 2007-09-14 | 2008-09-19 | 266d? | 124d | finish no earlier than 2008-09-19 | C4 | 2128h | 1064h | SIP_Nc-St2 |  |  | Rel-8 | Kimmo | TS 23.231 |  |  |
| 221 | 42.2 | Application of SIP-I Protocols to Circuit Switched (CS) core network architecture; Stage 3 |  | 266d? | 2007-09-14 A | 2008-09-19 | 20% | 212.8d? | 2007-09-14 | 2008-09-19 | 266d? | 124d | finish no earlier than 2008-09-19 | C4 | 2128h | 425.6h | SIP_Nc-St3 |  |  | Rel-8 | Kimmo | TS 29.231 |  |  |
| 222 | 42.3 | Interworking between the 3GPP CS domain with SIP-I as signalling protocol and other networks |  | 266d? | 2007-09-14 A | 2008-09-19 | 3% | 258.02d? | 2007-09-14 | 2008-09-19 | 266d? | 124d | finish no earlier than 2008-09-19 | C3 | 2128h | 63.84h | SIP_Nc-IW |  |  | Rel-8 | MEREDITH, John M | 29.235 |  |  |
| 223 | 43 | IMS Stage-3 IETF Protocol Alignment |  | 387d? | 2007-06-22 A | 2008-12-15 | 20% | 309.6d? | 2007-06-22 | 2008-09-05 | 316d? | 63d | finish no earlier than 2008-12-15 | C1 | 3096h | 619.2h | IMSProtoc2 | Keith Drage (Alcatel-Lucent) | drage@alcatel-lucent.com | Rel-8 | Andrijana | 23.218, 24.229 |  |  |
| 224 | 44 | New multicarrier BTS class |  | 126d? | 2007-08-31 | 2008-02-22 |  |  | 2007-08-31 | 2008-02-22 | 126d? | 274d | finish no earlier than 2008-02-22 | G1 | 1008h |  | MCBTS | Thomas BITZER (Alcatel-Lucent) | thomas.bitzer@alcatel-lucent.de | Rel-8 | Paolo | 45.005, 45.050, 51.021 |  |  |
| 225 | 45 | MS Antenna Performance Evaluation Method and Requirements |  | 731d? | 2005-01-28 A | 2007-11-16 A | 100% |  | 2005-01-28 | 2008-02-22 | 801d? |  | finish no earlier than 2007-11-16 | GP | 5848h | 5848h | APEMR | Ulf.Tegth (TeliaSonera) | Ulf.Tegth@teliasonera.com | Rel-8 | Paolo | 25.914, 25.144, 45.005 |  |  |
| 226 | 46 | U-TDOA Enhancement |  | 131d? | 2007-05-18 A | 2007-11-16 A | 100% |  | 2007-05-18 | 2008-02-22 | 201d? |  | finish no earlier than 2007-11-16 | GP | 1048h | 1048h | GUTEN | Ms. Terri L. Brooks, TruePosition, Inc. | terri.brooks@trueposition.com | Rel-8 | Paolo | 43.059, 45.008, 48.071 |  |  |
| 227 | 47 | **Paging Permission with Access Control** |  | 199d? | 2007-06-12 A | 2008-03-14 | 44% | 111.54d? |  |  |  | 259d |  | S1 | 2848h | 1104h | PPACR | Morita Takashi, NTT DoCoMo Inc. |  | Rel-8 | Alain | 22.011 |  |  |
| 228 | 47.1 | Stage 1 of PPACR |  | 69d? | 2007-06-12 A | 2007-09-14 A | 100% |  |  |  |  |  | finish no earlier than 2007-09-14 | S1 | 552h | 552h | PPACR-S1 | Morita Takashi, NTT DoCoMo Inc. |  | Rel-8 | Alain | 22.011 |  |  |
| 229 | 47.2 | Stage 3 (CT1) of PPACR |  | 88d? | 2007-11-14 | 2008-03-14 |  |  |  |  |  | 259d | finish no earlier than 2008-03-14 | C1 | 704h |  | PPACR-CT1 | Morita Takashi, NTT DoCoMo Inc. |  | Rel-8 | Andrijana | 24.008, 23.122 |  |  |
| 230 | 48 | **GAN Enhancements** |  | 261d? | 2007-08-31 A | 2008-08-29 | 16% | 218.51d? | 2007-08-31 | 2008-08-29 | 261d? | 139d |  | GP | 5184h | 504h | GANENH | Mohammed Versi, T-Mobile USA Inc. | mohammed.versi@t-mobile.com | Rel-8 | Paolo | 43.318, 44.318, 51.010 |  |  |
| 231 | 48.1 | Update to GAN specifications |  | 126d? | 2007-08-31 A | 2008-02-22 | 50% | 63d? | 2007-08-31 | 2008-02-22 | 126d? | 274d | finish no earlier than 2008-02-22 | GP | 1008h | 504h | GANENH-SPEC | Mohammed Versi, T-Mobile USA Inc. | mohammed.versi@t-mobile.com | Rel-8 | Paolo, Gert | 43.318, 44.318 |  |  |
| 232 | 48.2 | Update TS 51.010 Mobile Station (MS) Conformance Specification for GAN Enhancements |  | 261d? | 2007-08-31 | 2008-08-29 |  |  | 2007-08-31 | 2008-08-29 | 261d? | 139d | finish no earlier than 2008-08-29 | GP | 2088h |  | GANENH-MStest | Mohammed Versi, T-Mobile USA Inc. | mohammed.versi@t-mobile.com | Rel-8 | Stoyan | 51.010 |  |  |
| 233 | 49 | **Earthquake and Tsunami Warning System** |  | 131d? | 2007-09-10 A | 2008-03-10 | 70% | 39.3d? |  |  |  | 263d |  | S1 | 2096h | 1467.2h | ETWS | Ryo Kitahara (NTTDoCoMo) | kitaharar@nttdocomo.co.jp | Rel-8 | Alain |  |  |  |
| 234 | 49.1 | Stage 1 for ETWS |  | 131d? | 2007-09-10 A | 2008-03-10 | 70% | 39.3d? |  |  |  | 263d | finish no earlier than 2008-03-10 | S1 | 1048h | 733.6h | ETWS-S1 | Ryo Kitahara (NTTDoCoMo) | kitaharar@nttdocomo.co.jp | Rel-8 | Alain | 22.268 |  |  |
| 235 | 50 | **Multimedia interworking between IMS and CS networks** |  | 846d? | 2005-09-23 A | 2008-12-19 | 22% | 661.36d? | 2005-09-23 | 2007-05-11 | 426d? | 59d |  | C3 | 11720h | 1124.23h | MIWIMS | Nico Gabriele, Vodafone UK | nico.gabriele@vodafone.com | Rel-8 | Seung Don | 29.163, 29.332 |  |  |
| 236 | 50.1 | Note: Stages 1 and 2 defined in earlier Release |  | 49d? | 2005-09-23 A | 2005-11-30 A | 100% |  | 2005-09-23 | 2005-11-30 | 49d? |  | start no earlier than 2005-09-23 | S2 | 392h | 392h |  |  |  | Rel-8 |  |  |  |  |
| 237 | 50.2 | Stage 3 of MW-IMS, MONA extension |  | 287d? | 2007-11-05 A | 2008-12-09 | 30% | 200.9d? |  |  |  | 67d | finish no earlier than 2008-12-09 | C3 | 2296h | 688.8h | MWIMS-St3Ph2 |  |  | Rel-8 | MEREDITH, John M | 29.163 |  |  |
| 238 | 50.3 | Mn interface (MGCF – IM MGW) |  | 283d? | 2007-11-21 | 2008-12-19 |  |  |  |  |  | 59d | finish no earlier than 2008-12-19 | C4 | 2264h |  | MWIMS-Mn |  |  | Rel-8 |  | 29.332 |  |  |
| 239 | 51 | **Further development and enhancements to the Mp interface** |  | 266d? | 2007-11-30 | 2008-12-05 |  |  |  |  |  | 69d |  | C4 | 5944h |  | eMp | Chen cheng | Chencheng@huawei.com | Rel-8 | Kimmo | 23.333, 29.333 |  |  |
| 240 | 51.1 | Stage 2 of eMp |  | 211d? | 2007-11-30 | 2008-09-19 |  |  |  |  |  | 124d | finish no earlier than 2008-09-19 | C4 | 1688h |  | eMp | Chen cheng | Chencheng@huawei.com | Rel-8 | Kimmo | 23.333 |  |  |
| 241 | 51.2 | Stage 3 of eMp |  | 266d? | 2007-11-30 | 2008-12-05 |  |  |  |  |  | 69d | finish no earlier than 2008-12-05 | C4 | 2128h |  | eMp | Chen cheng | Chencheng@huawei.com | Rel-8 | Kimmo | 29.333 |  |  |
| 242 | 52 | Access Security Enhancements |  | 152d? | 2007-07-02 A | 2008-01-29 | 75% | 38d? | 2005-01-03 | 2005-09-30 | 195d? | 292d | start no earlier than 2007-07-01 | S3 | 1216h | 912h | ACCSEC2 | Bengt Sahlin, Ericsson | Bengt.Sahlin@ericsson.com | Rel-8 | Michael | 33.102, 43.020 | TSG |  |
| 243 | 53 | (Small) Technical Enhancements and Improvements for Rel-8 |  | 400d? | 2007-01-01 | 2008-07-11 |  |  | 2007-01-01 | 2008-07-11 | 400d? | 174d | start no earlier than 2007-01-01 | All | 3200h |  | TEI8 |  |  | Rel-8 |  |  |  |  |
| 244 | 54 | Deleted - was Rel7 - LCS for 3GPP Interworking WLAN | milestone | 0d? | 2007-09-28 | 2007-09-28 |  |  | 2006-10-23 | 2007-09-28 | 245d? | 379d | start no earlier than 2007-09-28 | S2 |  |  | LCS4_IWLAN | Donghee Shim (LG Electronics Inc.) | dhshim@lge.com | Rel-8 | Maurice | 23.234, 23.271, 23.167 |  | S2-56 |
| 245 | 55 | Deleted - never approved- FBI Phase 2 | milestone | 0d | 2007-09-28 | 2007-09-28 |  |  | 2006-06-30 | 2007-10-31 | 349d? | 379d | start no earlier than 2007-09-28 | S2 |  |  | FBI2 |  |  | Rel-8 | Maurice |  | TSG |  |
| 246 | 56 | Deleted - no support-Enhancements to BS30 Bearer service for Videotelephony | milestone | 0d? | 2007-03-15 A | 2007-03-15 A | 100% |  | 2007-01-04 | 2007-03-15 | 51d? |  | finish no earlier than 2007-03-15 | S1 |  |  | BS30 | Andre Jarvis (3) | andre.jarvis@three.co.uk | Rel-8 | Alain | 22.002, 22.004, 22.101, 22.105, 24.008 |  |  |
| 247 | 57 | Rel-8 Feasibility Studies |  | 1104d? | 2004-06-28 A | 2008-09-18 | 57% | 470.08d? | 2004-06-28 | 2008-09-18 | 1104d? | 125d |  | CT;RAN;SA | 8832h | 5071.4h |  |  |  | Rel-8 |  |  |  |  |
| 248 | 58 | Study on Facilitating Machine to Machine Communication in GSM and UMTS (M2M) |  | 161d? | 2005-11-04 A | 2006-06-16 A | 100% |  | 2005-11-04 | 2006-06-16 | 161d? |  | finish no earlier than 2006-06-16 | S1 | 1288h | 1288h | M2M | Juergen Merkel, Siemens AG |  | Rel-8 | Alain | 22.868 |  |  |
| 249 | 59 | Study on Network Composition |  | 211d? | 2005-12-07 A | 2006-09-27 A | 100% |  | 2005-12-07 | 2006-09-27 | 211d? |  | finish no earlier than 2006-09-27 | S1 | 1688h | 1688h | NetComp | Joerg Swetina (Siemens) | joerg.swetina@siemens.com | Rel-8 | Alain | 22.980 |  |  |
| 250 | 60 | Study on Charging Aspects of 3GPP System Evolution |  | 179d? | 2007-04-02 A | 2007-12-06 A | 100% |  | 2007-04-02 | 2007-12-06 | 179d? |  | finish no earlier than 2007-12-06 | S5 | 1432h | 1432h | FSSAEcharg | NSN |  | Rel-8 |  | TR 32.820 |  | SP-32 |

Notes:
- 222: CP-37: WI corrected. C3-36: Skeleton of TR 29.235 available.
- 225: Moved from Rel7
- 226: Moved from Rel7
- 227: Forgotten after SA#36
- 228: Forgotten after SA#36
- 229: CT1-50: C1-072820
- 235: C3-36: Rel-8 stage 3 (MONA) extension added, so Feature moved to Rel-8 (all Rel-7 aspects completed); revised WID in C3-071150.
- 236: Moved from FS section Feb 06
- 237: C3-46: New stage 3 element to cater for MONA extension.
- 242: Moved from Rel-7 to Rel-8 at SA#38
- 244: New WID approved SP-34. Supporting companies: Telcordia, Samsung, Qualcomm, BT, LG Electronics, Cingular, Alcatel-Lucent. No scheduled end date!
- 245: Added by MCC as a consequence of the move to Rel8 of TISPAN Rel-2 impacts on 3GPP
- 250: WID approved SA#35

| ID | WBS | Task | Duration | Start | Finish | Complete | Remaining | Baseline start | Baseline finish | Baseline duration | Total slack | Constraint | Resources | Work | Actual work | Text1 | Text3 | Text4 | Text5 | Text6 | Text7 | Text8 | Text12 |
| --- | --- | --- | --- | --- | --- | --- | --- | --- | --- | --- | --- | --- | --- | --- | --- | --- | --- | --- | --- | --- | --- | --- | --- |
| 251 | 61 | **Study on All-IP Network** | 448d? | 2004-06-28 A | 2006-03-15 A | 100% |  | 2004-06-28 | 2006-03-15 | 448d? |  |  | S1 | 8672h | 8672h | AIPN | 22.978 | Chris Sachno (NTT DoCoMo) | c.masyu@nttdocomo.co.jp | Rel-8 | TSG | Alain |  |
| 252 | 61.1 | All-IP Network Feasibility Study | 188d? | 2004-06-28 A | 2005-03-16 A | 100% |  | 2004-06-28 | 2005-03-16 | 188d? |  | start no earlier than 2004-06-28 | S1 | 1504h | 1504h | AIPFS | 22.978 | Chris Sachno (NTT DoCoMo) | c.masyu@nttdocomo.co.jp | Rel-8 | TSG | Alain |  |
| 253 | 61.2 | draft Stage 1 | 448d? | 2004-06-28 A | 2006-03-15 A | 100% |  | 2004-06-28 | 2006-03-15 | 448d? |  | finish no earlier than 2006-03-15 | S1 | 3584h | 3584h | AIPN | 22.258 | Chris Sachno (NTT DoCoMo) | c.masyu@nttdocomo.co.jp | Rel-8 | TSG | Alain |  |
| 254 | 62 | Study on Stage 2 aspects of IMS Service Brokering | 520d? | 2006-06-19 A | 2008-06-13 | 55% | 234d? | 2006-06-19 | 2008-03-14 | 455d? | 194d | finish no earlier than 2008-06-13 | S2 | 4160h | 2288h | ISB_ST2_SDY | 23.810 | Raquel Morera (Telcordia); F. Joe Lin (Telcordia) | raquel@research.telcordia.com | Rel-8 |  | Maurice |  |
| 255 | 63 | Study of Requirements of IMS Multimedia Conferencing | 205d? | 2006-06-08 A | 2007-03-21 A | 100% |  | 2006-06-08 | 2007-03-21 | 205d? |  | finish no earlier than 2007-03-21 | S1 | 1640h | 1640h | SI-IMSconf | 22.948 | Zheng Jianping (China Mobile ) | zhengjianping@chinamobile.com | Rel-8 |  | Alain |  |
| 256 | 64 | Study on support of a Public Warning System | 431d? | 2006-06-08 A | 2008-01-31 | 95% | 21.55d? | 2006-06-08 | 2007-03-21 | 205d? | 290d | finish no earlier than 2008-01-31 | S1 | 3448h | 3275.6h | FSPWS | 22.968 | Mark Young (T-mobile) | mark.younge@t-mobile.com | Rel-8 |  | Alain |  |
| 257 | 65 | Study on Protection against SMS and MMS spam | 402d? | 2006-06-08 A | 2007-12-21 | 10% | 361.8d? | 2006-06-08 | 2007-12-21 | 402d? | 319d | finish no earlier than 2007-12-21 | S3 | 3216h | 321.6h | CPSMal | 33.9xx | Eric Gauthier (Orange SA) | eric.gauthier@orange.ch | Rel-8 |  | Dioniso |  |
| 258 | 66 | Study of VCC support for Emergency Calls | 532d? | 2006-06-08 A | 2008-06-20 | 30% | 372.4d? | 2006-06-08 | 2008-06-20 | 532d? | 189d | finish no earlier than 2008-06-20 | S2 | 4256h | 1276.8h | FSVCCEm | 23.826 | Ricky Kaura, Nortel |  | Rel-8 |  | Maurice |  |
| 259 | 67 | **Study on centralized IMS services** | 290d? | 2006-10-23 A | 2007-12-01 | 87% | 36.57d? |  |  |  | 334d |  | S1; S2 | 7104h | 5572.74h | FSCIS | 22.892, 23.892 | Peter Bleckert, Ericsson | peter.bleckert@ericsson.com | Rel-8 |  |  |  |
| 260 | 67.1 | Study on centralized IMS services requirements | 192d? | 2007-03-05 A | 2007-11-27 | 91% | 17.28d? |  |  |  | 337d | start no earlier than 2007-03-05 | S1 | 1536h | 1397.76h | FSCIS-St1 | 22.892, 23.892 | Peter Bleckert, Ericsson | peter.bleckert@ericsson.com | Rel-8 |  |  |  |
| 261 | 67.2 | Study on centralized IMS services control | 290d? | 2006-10-23 A | 2007-12-01 | 85% | 43.5d? | 2006-10-23 | 2007-12-01 | 290d? | 334d | finish no earlier than 2007-12-01 | S2 | 2320h | 1972h | IMS_CSC | 23.892 | Andy Bennett (Alcatel-Lucent) | andybennett@Alcatel-Lucent.com | Rel-8 |  | Maurice |  |
| 262 | 68 | Study on IMS utilizing multicast bearer services | 444d? | 2006-03-22 A | 2007-12-03 A | 100% |  | 2006-03-22 | 2007-12-03 | 444d? |  | finish no earlier than 2007-12-03 | S2 | 3552h | 3552h | FS-MLTICAST-IMS | 23.847 | Fiona Zhu (Siemens AG) |  | Rel-8 |  | Maurice |  |
| 263 | 69 | Study on Paging Permission with Access Control | 256d? | 2006-09-28 A | 2007-09-20 A | 100% |  | 2006-09-28 | 2007-09-20 | 256d? |  | finish no earlier than 2007-09-20 | S1 | 2048h | 2048h | PPAC | 22.908 | Katsuhiro Noguchi (NTT DoCoMo Inc.) | noguchi@nttdocomo.co.jp | Rel-8 |  | Alain |  |
| 264 | 70 | Study on Non 3GPP access NSP | 249d? | 2006-12-06 A | 2007-11-19 A | 100% |  | 2006-12-06 | 2007-09-20 | 207d? |  | finish no earlier than 2007-11-19 | S1 | 1992h | 1992h | N3GtoNSP | 22.812 | Chris Friel (O2) | chris.friel@o2.com | Rel-8 |  | Alain |  |
| 265 | 71 | Study on Value Added Services for Short Message Service | 263d? | 2006-12-06 A | 2007-12-07 A | 100% |  | 2006-12-06 | 2007-12-07 | 263d? |  | finish no earlier than 2007-12-07 | S1 | 2104h | 2104h | FSVAS4SMS | 22.942 | Wu Bin (China Mobile Communications Corporation) | wubin@chinamobile.com | Rel-8 |  | Alain |  |
| 266 | 72 | Study on Service continuity between mobile and WLAN networks | 262d? | 2006-12-06 A | 2007-12-06 | 90% | 26.2d? | 2006-12-06 | 2007-12-06 | 262d? | 330d | finish no earlier than 2007-12-06 | S1 | 2096h | 1886.4h | SMLSWLAN | 22.937 | Mike Meyerstein (BT) | mike.meyerstein@bt.com | Rel-8 |  | Alain |  |
| 267 | 73 | Study of Mobility between 3GPP-WLAN Interworking and 3GPP Systems | 129d? | 2007-03-20 A | 2007-09-14 A | 100% |  | 2007-03-20 | 2007-09-14 | 129d? |  | start no earlier than 2007-03-20 | S2 | 1032h | 1032h | SM3GWLAN | 23.837 | Orange | orange | Rel-8 |  | Maurice |  |
| 268 | 74 | **OAM&P Rel-8 Studies** | 612d? | 2006-05-10 A | 2008-09-11 | 64% | 223.31d? | 2005-09-02 | 2008-06-12 | 725d? | 130d |  | S5 | 17217.6h | 9420h | OAM8-Studies |  |  |  | Rel-8 |  | Adrian |  |
| 269 | 74.1 | Study of Element Operations Systems Function (EOSF) definition | 331d? | 2007-06-07 A | 2008-09-11 | 30% | 231.7d? | 2005-09-02 | 2007-12-14 | 596d? | 130d | finish no earlier than 2008-09-11 | S5 | 2648h | 794.4h |  | TR 32.819 | China Mobile |  | Rel-8 |  |  | SP-32 |
| 270 | 74.2 | Study on SA5 MTOSI XML Harmonization | 351d? | 2006-05-10 A | 2007-09-12 A | 100% |  | 2006-05-10 | 2007-12-14 | 418d? |  | finish no earlier than 2007-12-14 | S5 | 2808h | 2808h |  | TR 32.818 | Nortel |  | Rel-8 |  |  | SP-32 |
| 271 | 74.3 | Study of Common Profile Storage (CPS) Framework of User Data for network services and management | 244d? | 2006-07-03 A | 2007-06-07 A | 100% |  | 2006-07-03 | 2007-06-07 | 244d? |  | finish no earlier than 2007-06-07 | S5 | 1952h | 1952h |  | TR 32.808 | T-Mobile |  | Rel-8 |  |  |  |
| 272 | 74.4 | Study of Management for LTE and SAE | 396d? | 2006-12-07 A | 2008-06-12 | 75% | 99d? | 2006-12-07 | 2007-09-14 | 202d? | 195d | finish no earlier than 2008-06-12 | S5 | 3168h | 2376h |  | TR 32.816 | Ericsson |  | Rel-8 |  |  |  |
| 273 | 74.5 | Study of System Maintenance by Itf-N | 266d? | 2007-06-07 A | 2008-06-12 | 40% | 159.6d? | 2007-06-07 | 2008-06-12 | 266d? | 195d | finish no earlier than 2008-06-12 | S5 | 2128h | 851.2h |  | TR 32.822 | ZTE |  | Rel-8 |  |  |  |
| 274 | 74.6 | Study of Self-Organizing Networks (SON) related OAM interfaces for Home NodeB | 266d? | 2007-06-07 A | 2008-06-12 | 30% | 186.2d? | 2007-06-07 | 2008-06-12 | 266d? | 195d | finish no earlier than 2008-06-12 | S5 | 2128h | 638.4h |  | TR 32.821 | Huawei |  | Rel-8 |  |  |  |
| 275 | 75 | Study on AS-MRFC media server control protocol | 518d? | 2006-03-22 A | 2008-03-15 | 90% | 51.8d? | 2006-03-22 | 2007-12-21 | 458d? | 259d | finish no earlier than 2008-03-15 | C1 | 4144h | 3729.6h | MRFC | 24.880 | Mark Syrett (Hewlett-Packard) | mark.syrett@hp.com | Rel-8 |  | Andrijana |  |
| 276 | 76 | Study on Restoration Procedures | 255d? | 2007-03-26 A | 2008-03-14 | 65% | 89.25d? | 2007-03-26 | 2007-11-30 | 180d? | 259d | finish no earlier than 2008-03-14 | C4 | 2040h | 1326h | FSIMS8_RP | TR 23.820 | German Blanco (Ericsson) | german.blanco@ericsson.com | Rel-8 |  | Kimmo |  |
| 277 | 77 | Study on 3G Home NodeB/eNodeB | 210d? | 2007-03-05 A | 2007-12-21 | 10% | 189d? | 2007-03-05 | 2007-12-21 | 210d? | 319d | finish no earlier than 2007-12-21 | R4 | 1680h | 168h | RANFS-HNBeNB |  | Howard Thomas (Motorola) |  | Rel-8 |  | Claude |  |
| 278 | 78 | Study on Multimedia Session Continuity | 232d? | 2007-04-26 A | 2008-03-14 | 60% | 92.8d? | 2007-04-26 | 2008-03-14 | 232d? | 259d | finish no earlier than 2008-03-14 | S2 | 1856h | 1113.6h | MMSC_FS | 23.893 | Jaeseung Song (LG Electronics) |  | Rel-8 |  | Maurice |  |
| 279 | 79 | Study on CS Domain Services over evolved PS access | 233d? | 2007-04-25 A | 2008-03-14 | 70% | 69.9d? | 2007-04-25 | 2008-03-14 | 233d? | 259d | finish no earlier than 2008-03-14 | S2 | 1864h | 1304.8h | FS_CSoPS | 23.879 | Sabine Demel (T-Mobile International) | Sabine(dot)Demel(at)T-Mobile(dot)at | Rel-8 |  | Maurice |  |
| 280 | 80 | Study on Transferring of emergency call data – in-band modem solution | 466d? | 2006-12-07 A | 2008-09-18 | 60% | 186.4d? | 2006-12-07 | 2008-09-18 | 466d? | 125d | finish no earlier than 2008-09-18 | S4 | 3728h | 2236.8h | eCALLIBMS | 26.967 | Leon Hong, Airbiquity | lhong@airbiquity.com | Rel-8 |  | Paolo |  |
| 281 | 81 | Study on Improved network controlled mobility between LTE and 3GPP2/mobile WiMAX radio technologies | 131d? | 2007-06-04 A | 2007-12-03 | 50% | 65.5d? | 2007-06-04 | 2007-12-03 | 131d? | 333d | finish no earlier than 2007-12-03 | R2 | 1048h | 524h | RANFS-LTEmob | 25.9xx | Hao Bi, Motorola | hao.bi@Motorola.com | Rel-8 |  | Claude |  |
| 282 | 82 | Study on IMS Application Server Service Data Descriptions for AS interoperability | 131d? | 2007-09-14 A | 2008-03-14 | 10% | 117.9d? | 2007-09-14 | 2008-03-14 | 131d? | 259d | finish no earlier than 2008-03-14 | C4 | 1048h | 104.8h | FSIMS8_ASIO | TR 29.864 | Nigel Berry (Alcatel-Lucent | nhberry@ALCATEL-LUCENT.COM | Rel-8 |  | Kimmo |  |

Notes:
- 253: 22.258 withdrawm, superseded by 22.278 (UID 320022)
- 254: Study approved SA#32
- 256: Acronym changed from "PWS-SI" to "FSPWS"
- 257: Formerly called "Consumer protection against spam and malware"
- 258: Rapporteur update S2#59
- 259: 22.892 planed to be withdrawn at SA#40
- 260: 22.892 planed to be withdrawn at SA#40
- 261: Name changed from "Study on Centralised IMS Service Control"
- 266: Name changed from "Study on Requirements for seamless roaming and service continuity between mobile and WLAN networks"
- 268: Created to encompass the Rel7 Work Tasks shifted to Rel8
- 278: SID approved at SP-36. Updated as SP-37. For information to SA#38
- 279: SID approved at SP-36. TR for information to SA#38
- 280: Moved from Rel7

| ID | WBS | Task | Type | Duration | Start | Finish | Complete | Remaining | Baseline start | Baseline finish | Baseline duration | Total slack | Constraint | Resources | Work | Actual work | Text1 | Text3 | Text5 | Text6 | Text8 | Text7 |
| --- | --- | --- | --- | --- | --- | --- | --- | --- | --- | --- | --- | --- | --- | --- | --- | --- | --- | --- | --- | --- | --- | --- |
| 283 | 83 | **Study on CAT solution for voice and video call in CS domain** |  | 150.65d? | 2007-09-14 A | 2008-04-11 | 8% | 139.35d? | 2007-09-14 | 2008-03-14 | 131d? | 239.35d |  | C4 | 3301.2h | 247.59h | FSCusAlert-St3 | TR 29.882 | zhanghao@chinamobile.com | Rel-8 | Kimmo |  |
| 284 | 83.1 | Study on CAT solution for voice and video call in CS domain |  | 131d? | 2007-09-14 A | 2008-03-14 | 15% | 111.35d? | 2007-09-14 | 2008-03-14 | 131d? | 259d | finish no earlier than 2008-03-14 | C4 | 1048h | 157.2h | FSCusAlert-St3 | TR 29.882 | zhanghao@chinamobile.com | Rel-8 | Kimmo |  |
| 285 | 83.2 | CT3 Review of CT4's Study on CAT |  | 131d? | 2007-09-14 A | 2008-04-11 |  | 131d? | 2007-09-14 | 2008-03-14 | 131d? | 239.35d | finish no earlier than 2008-03-14 | C3 | 1048h |  | FSCusAlert-St3_rev | TR 29.882 | zhanghao@chinamobile.com | Rel-8 | Kimmo |  |
| 286 | 84 | **Study on 3GPP System Architecture Evolution** |  | 802d? | 2004-12-03 A | 2007-12-31 | 96% | 32.32d? | 2004-12-03 | 2007-09-28 | 736d? | 313d |  | S2 | 12392h | 11892.7h | SAE |  |  | Rel-8 | Dioniso | TSG |
| 287 | 84.1 | Stage 2 Interim conclusion for RAN Work to start |  | 211d? | 2004-12-03 A | 2005-09-23 A | 100% |  | 2004-12-03 | 2005-09-23 | 211d? |  | finish no earlier than 2005-09-23 | S2 | 1688h | 1688h |  | 23.882 |  | Rel-8 |  |  |
| 288 | 84.2 | Stage 2 study on 3GPP architectural development |  | 450d? | 2006-01-09 A | 2007-09-28 A | 100% |  | 2006-01-09 | 2007-09-28 | 450d? |  | finish no earlier than 2007-09-28 | S2 | 3600h | 3600h |  | 23.882 |  | Rel-8 | Maurice |  |
| 289 | 84.3 | Security study for Inter-access mobility between non 3GPP and 3GPP system |  | 86d? | 2007-09-03 A | 2007-12-31 | 65% | 30.1d? | 2006-02-03 | 2006-06-02 | 86d? | 313d | start no earlier than 2007-09-01 | S3 | 688h | 447.2h | SAE-Sec | 23.882, 33.821, 33.922 | dajiang.zhang@NOKIA.COM | Rel-8 | Dioniso |  |
| 290 | 85 | Study on Scope of future HSPA Evolution for 1.28Mcps TDD |  | 175d? | 2007-09-14 | 2008-05-15 |  |  | 2007-09-14 | 2008-05-15 | 175d? | 215d | finish no earlier than 2008-05-15 | R1 | 1400h |  | RANFS-LCRTDDHSPAEvo | TR 25.9xx |  | Rel-8 | Claude |  |
| 291 | 86 | Study on Synchronised E-DCH for UTRA FDD |  | 131d? | 2007-09-14 | 2008-03-14 |  |  | 2007-09-14 | 2008-03-14 | 131d? | 259d | finish no earlier than 2008-03-14 | R1 | 1048h |  | RANFS-UplinkSync | TR 25.9xx | Karri.Ranta-aho@nsn.com | Rel-8 | Claude |  |
| 292 | 87 | Study on Extended Support of IMS Emergency Calls |  | 125d? | 2007-09-24 A | 2008-03-14 | 5% | 118.75d? | 2007-09-24 | 2008-03-14 | 125d? | 259d | finish no earlier than 2008-03-14 | S2 | 1000h | 50h | FSExIMSEm | 23.868 |  | Rel-8 | Maurice |  |
| 293 | 88 | **Study on enhanced voice service requirements for the EPS** |  | 140d? | 2007-09-03 A | 2008-03-14 | 16% | 118.3d? | 2007-09-03 | 2008-03-14 | 140d? | 259d |  | S1 | 3360h | 520.8h | FSEV_EPS | new TR 22.xxx | tim.haysom@orange-ftgroup.com | Rel-8 |  |  |
| 294 | 88.1 | Use cases definition and service and system requirements |  | 140d? | 2007-09-03 A | 2008-03-14 | 31% | 96.6d? |  |  |  | 259d | start no earlier than 2007-09-03 | S1 | 1120h | 347.2h | FSEV_EPS-S1 |  | tim.haysom@orange-ftgroup.com | Rel-8 |  |  |
| 295 | 88.2 | Codec specific part of FSEV_EPS |  | 140d? | 2007-09-03 | 2008-03-14 |  |  |  |  |  | 259d | start no earlier than 2007-09-03 | S4 | 1120h |  | FSEV_EPS-S4 |  | tim.haysom@orange-ftgroup.com | Rel-8 |  |  |
| 296 | 89 | Study on System enhancements for the use of IMS services in local breakout |  | 170d? | 2007-10-01 | 2008-05-23 |  |  | 2007-09-03 | 2007-12-14 | 75d? | 209d | finish no earlier than 2008-05-23 | S2 | 1360h |  | FSIMS_LBO | 22.8xx |  | Rel-8 | Maurice |  |
| 297 | 90 | Study on Services Alignment and Migration |  | 256d? | 2006-12-06 A | 2007-11-28 A | 100% |  | 2006-12-06 | 2007-11-28 | 256d? |  | finish no earlier than 2007-09-20 | S1 | 2048h | 2048h | FSServAl | 22.983 | fenglingjuan@chinamobile.com | Rel-8 | Alain |  |
| 298 | 91 | Study on A-interface over IP |  | 126d? | 2007-08-31 A | 2008-02-22 | 50% | 63d? |  |  |  | 274d | finish no earlier than 2008-02-22 | GP | 1008h | 504h | AINTIP | TR 43.903 | paul.schliwa-bertling@ericsson.com | Rel-8 | Paolo, Gert |  |
| 299 | 92 | Study on Multi-User Reusing-One-Slot |  | 131d? | 2007-11-16 | 2008-05-16 |  |  |  |  |  | 214d | finish no earlier than 2008-05-16 | GP | 1048h |  | MUROS | TR | juergen.hofmann@nsn.com | Rel-8 | Paolo |  |
| 300 | 93 | Study on InterWorking Function between MAP based and Diameter based interfaces |  | 211d? | 2007-11-30 | 2008-09-19 |  |  |  |  |  | 124d | finish no earlier than 2008-09-19 | C4 | 1688h |  | FSMAP2Diam | 29.8xy | liming49985@HUAWEI.COM | Rel-8 | Kimmo |  |
| 301 | 94 | Deleted - equals 340035 -FS on Service continuity between mobile and WLAN networks |  | 75d? | 2007-09-03 | 2007-12-14 |  |  | 2007-09-03 | 2007-12-14 | 75d? | 324d | finish no earlier than 2007-12-14 | S1 | 600h |  | FSSCMobToW | 22.937 | mike.meyerstein@bt.com | Rel-8 |  |  |
| 302 | 95 | Deleted - Study on GAN Enhancements |  | 206d? | 2006-11-17 A | 2007-08-31 A | 100% |  | 2006-11-17 | 2007-08-31 | 206d? |  | start no earlier than 2006-11-17 | GP | 1648h | 1648h | EGAN | 43.902 | janne.linkola@t-mobile.com | Rel-7 | Paolo |  |
| 303 | 96 | Release 9 Features | milestone | 0d? | 2007-09-19 | 2007-09-19 |  |  | 2000-01-03 | 2000-01-03 | 1d? | 387d | finish no earlier than 2007-09-19 | CT;RAN;SA |  |  |  |  |  | Rel-9 |  |  |
| 304 | 97 | End-User Identity |  | 75d? | 2007-09-03 A | 2007-12-14 | 5% | 71.25d? | 2007-09-03 | 2007-12-14 | 75d? | 324d | finish no earlier than 2007-12-14 | S1 | 600h | 30h | EUI | 22.101 | Joerg.Swetina@Siemens.com | Rel-9 |  |  |
| 305 | 98 | Rel-9 Feasibility Studies | milestone | 0d | 2007-09-19 | 2007-09-19 |  |  | 2004-06-28 | 2008-09-18 | 1104d? | 387d | start no earlier than 2007-09-19 | CT;RAN;SA |  |  |  |  |  | Rel-9 |  |  |
| 306 | 99 | Study on Remote management of USIM application on M2M Equipment |  | 263d? | 2007-09-19 A | 2008-09-19 | 20% | 210.4d? |  |  |  | 124d | finish no earlier than 2008-09-19 | S3 | 2104h | 420.8h | FSUM2M | 33.8yz | vesa.lehtovirta@ericsson.com | Rel-9 |  |  |

Notes:
- 283: Text4: Zhang Hao (China Mobile)
- 284: Text4: Zhang Hao (China Mobile)
- 285: Text4: Zhang Hao (China Mobile)
- 286: Moved from Rel-7
- 287: Moved from Rel-7
- 288: Moved from Rel-7 / Text4: Chris Pudney
- 289: Moved from Rel-7 / Text4: Dajiang Zhang (Nokia)
- 290: Text4: Xu Fei, RITT
- 291: Text4: Karri Ranta-aho, Nokia Siemens Networks
- 292: Approved SP-37 / Text4: Stephen Edge (Qualcomm)
- 293: Text4: Tim Haysom, Orange
- 294: Text4: Tim Haysom, Orange
- 295: Text4: Tim Haysom, Orange
- 296: SID approved SA#37 / Text4: Mario Madella, Telecom Italia
- 297: Created at SA1#38 to dissociate TR from TS / Text4: Feng Lingjuan (China Mobile)
- 298: Text4: Wang Shuaiyu, China Mobile and Paul Schliwa-Bertling, Ericsson
- 299: Text4: Juergen Hofmann (Nokia Siemens Networks)
- 300: Text4: Li Ming
- 301: Text4: Mike Meyerstein, BT
- 302: Completed for Rel7 / Text4: Janne Linkola (T-Mobile)
- 304: Moved to Rel-9 at SA1#38 / Text4: Joerg Swetina (Nokia Siemens Network)
- 306: Text4: Vesa Lehtovirta (Ericsson)
